# Dorado2002revC

How a schedule from MS Project changed from version to version. A marks actual dates.

## Version 1 (saved 2002-05-13, file Dorado2002revC.mpp)

| ID | WBS | Task | Duration | Start | Finish | Predecessors | Complete | Total float | Constraint |
| --- | --- | --- | --- | --- | --- | --- | --- | --- | --- |
| 1 | 1 | **Dorado Program** | 178d? | 2002-03-15 A | 2002-11-19 |  | 8% | 0d |  |
| 3 | 1.1 | **Propulsion** | 99d | 2002-05-02 A | 2002-09-17 |  | 1% | 45d |  |
| 4 | 1.1.1 | **Articulated Tail** | 95d | 2002-05-02 | 2002-09-11 |  |  | 45d |  |
| 5 |  | Design & Build New Electronics Housing | 10d | 2002-05-02 | 2002-05-15 |  |  | 130d | start no earlier than 2002-05-02 |
| 6 |  | New Linear Actuator Scheme | 7d | 2002-09-03 | 2002-09-11 |  |  | 45d | start no earlier than 2002-09-03 |
| 7 | 1.1.2 | **Drive Electronics** | 24d | 2002-05-06 | 2002-06-06 |  |  | 113d |  |
| 8 |  | Integrate New Electroincs | 24d | 2002-05-06 | 2002-06-06 |  |  | 112d | start no earlier than 2002-05-05 |
| 9 |  | Cabling | 5d | 2002-05-27 | 2002-05-31 |  |  | 116d | start no earlier than 2002-05-27 |
| 10 |  | Integrate New Tail Into fairing | 5d | 2002-06-07 | 2002-06-13 | 7 |  | 112d |  |
| 11 |  | Tailcone - Bench Stand Design and Fab | 3d | 2002-05-27 | 2002-05-29 |  |  | 124d | start no earlier than 2002-05-27 |
| 12 |  | Buoyancy Check / Test | 1d | 2002-06-14 A | 2002-06-14 A | 10 | 100% |  |  |
| 13 |  | Test Plan | 5d | 2002-06-14 | 2002-06-20 |  |  | 108d | start no earlier than 2002-06-14 |
| 14 | 1.1.7 | **Tailcone Documetation** | 4d | 2002-09-12 | 2002-09-17 | 7, 4 |  | 45d |  |
| 15 |  | Mechanical | 3d | 2002-09-12 | 2002-09-16 |  |  | 46d |  |
| 16 |  | Electrical | 2d | 2002-09-12 | 2002-09-13 |  |  | 47d | start no earlier than 2002-09-02 |
| 17 |  | Software | 4d | 2002-09-12 | 2002-09-17 |  |  | 45d | start no earlier than 2002-09-04 |
| 19 | 1.2 | **Power** | 51d? | 2002-04-15 A | 2002-06-24 |  | 9% | 163d |  |
| 20 | 1.2.1 | **Battery Chemistry** | 29d | 2002-04-15 A | 2002-05-23 |  | 15% | 182d |  |
| 21 |  | Check life on current Ag-Zn batteries | 4d | 2002-04-15 A | 2002-04-18 |  | 66% | 119d | start no earlier than 2002-04-13 |
| 22 |  | Trade study to review Batt Chems | 3d | 2002-04-18 A | 2002-04-22 |  | 80% | 117d | start no earlier than 2002-04-18 |
| 23 |  | Thermal Analysis of Battery Pack | 5d | 2002-04-17 | 2002-04-23 |  |  | 116d | start no earlier than 2002-04-17 |
| 24 |  | Design Review of Batt Chems | 1d | 2002-04-24 | 2002-04-24 | 21, 22, 23 |  | 116d |  |
| 25 |  | Purchase Batteries | 1d | 2002-04-25 | 2002-04-25 | 24 |  | 182d |  |
| 26 |  | Assemble Batteries | 5d | 2002-04-26 | 2002-05-02 | 25 |  | 182d |  |
| 27 |  | Test Batteries | 15d | 2002-05-03 | 2002-05-23 | 26 |  | 182d |  |
| 28 | 1.2.2 | **Battery Housing** | 34d | 2002-04-25 A | 2002-06-11 | 24 | 12% | 172d |  |
| 29 |  | Design | 10d | 2002-05-01 | 2002-05-14 |  |  | 172d | start no earlier than 2002-05-01 |
| 30 |  | Build | 15d | 2002-05-15 | 2002-06-04 | 29 |  | 172d |  |
| 31 |  | Test | 5d | 2002-06-05 | 2002-06-11 | 30 |  | 172d |  |
| 32 |  | Spec Interconnects | 4d | 2002-04-25 A | 2002-04-30 A |  | 100% |  | start no earlier than 2002-03-28 |
| 33 | 1.2.3 | **Battery Electronics** | 29d? | 2002-05-01 | 2002-06-10 | 24, 32 |  | 171d |  |
| 34 |  | Concept Design | 5d | 2002-05-01 | 2002-05-07 |  |  | 179d | start no earlier than 2002-04-22 |
| 35 |  | Design Review | 2d | 2002-05-08 | 2002-05-09 | 34 |  | 179d |  |
| 36 |  | Final Design | 11d | 2002-05-10 | 2002-05-24 | 35 |  | 179d | start no earlier than 2002-05-01 |
| 37 |  | Build | 1d | 2002-05-27 | 2002-05-27 | 36 |  | 179d |  |
| 38 |  | Assemble | 1d | 2002-05-28 | 2002-05-28 | 37 |  | 179d |  |
| 39 |  | Test | 1d | 2002-05-29 | 2002-05-29 | 38 |  | 179d |  |
| 40 |  | Spec Misc Electronics (Contingency) | 1d? | 2002-06-10 | 2002-06-10 | 27 |  | 171d | start no earlier than 2002-06-10 |
| 41 | 1.2.4 | **Battery Charging** | 2d | 2002-06-11 | 2002-06-12 | 24, 33 |  | 171d |  |
| 42 |  | Spec Charging Analysis | 2d | 2002-06-11 | 2002-06-12 |  |  | 171d |  |
| 43 |  | Order Charging Equip as Required | 1d | 2002-06-11 | 2002-06-11 |  |  | 172d |  |
| 44 |  | AUV Power Systems Meeting | 4d | 2002-06-19 | 2002-06-24 |  |  | 163d | start no earlier than 2002-06-19 |
| 46 | 1.3 | **Cabling and Connectors** | 42d | 2002-04-25 A | 2002-06-21 | 24 | 41% | 107d |  |
| 47 |  | Spec Main Power / Comms Cable&Connectors/Penetrators | 13d | 2002-04-25 A | 2002-05-13 |  | 50% | 124.66d |  |
| 48 |  | Spec Charging Connector | 4d | 2002-05-14 | 2002-05-17 | 47 |  | 132d |  |
| 49 |  | Spec Tailcone Comms Cable&Connector/Penetrator | 3d | 2002-04-25 A | 2002-04-29 |  | 80% | 134.66d | start no earlier than 2002-03-18 |
| 50 |  | Spec Science Instrument Connector | 2d | 2002-04-25 A | 2002-04-26 A |  | 100% |  | start no earlier than 2002-04-24 |
| 51 |  | Spec DVL and parosci Connectors / Penetrator | 1d | 2002-04-29 A | 2002-04-29 A | 50 | 100% |  |  |
| 52 |  | Spec RF/Acoustic/Emer location Connect & Penetrators | 1d | 2002-04-30 A | 2002-04-30 A | 51 | 100% |  |  |
| 53 |  | Spec On/Off Connector/Penetrator | 1d | 2002-05-01 A | 2002-05-01 A | 52 | 100% |  |  |
| 54 |  | Test ability of 100 MB/s thrugh current ALTEX Cable | 2d | 2002-05-21 A | 2002-05-22 A |  | 100% |  | start no earlier than 2002-05-21 |
| 55 |  | Order Connectors | 2d | 2002-05-14 A | 2002-05-15 | 47, 49, 53 | 33% | 124d |  |
| 56 | 1.3.10 | **Tail to MVC** | 1d | 2002-05-09 | 2002-05-09 |  |  | 128d |  |
| 57 |  | Section Interconnect | 1d | 2002-05-09 | 2002-05-09 |  |  | 128d | start no earlier than 2002-05-09 |
| 58 |  | Documetation package on Connectors and Cabling | 10d | 2002-06-10 | 2002-06-21 | 55, 57 |  | 107d | start no earlier than 2002-06-10 |
| 60 | 1.4 | **Main Vehicle Computer** | 135d | 2002-03-15 A | 2002-09-19 |  | 33% | 43d |  |
| 61 | 1.4.1 | **Electronics** | 59d | 2002-03-15 A | 2002-06-05 |  | 45% | 119d |  |
| 62 |  | Spec PC 104 Stack | 2d | 2002-03-15 A | 2002-03-18 A |  | 100% |  |  |
| 63 |  | Order PC 104 Stack | 2d | 2002-03-19 A | 2002-05-07 | 62 | 40% | 138.8d |  |
| 64 |  | Assemble PC 104 Stack | 2d | 2002-05-07 | 2002-05-09 | 63 |  | 138.8d |  |
| 65 |  | Develop latency test/budget for MVC | 4d | 2002-05-13 | 2002-05-16 |  |  | 133d | start no earlier than 2002-05-11 |
| 66 | 1.4.1.5 | **Power Board** | 23d | 2002-04-28 A | 2002-05-29 | 24 | 50% | 114d |  |
| 67 |  | Specify | 4d | 2002-04-28 A | 2002-05-02 A |  | 100% |  | start no earlier than 2002-05-06 |
| 68 |  | Design | 15d | 2002-05-03 A | 2002-05-23 | 67 | 50% | 114d |  |
| 69 |  | Order | 1d | 2002-05-24 | 2002-05-24 | 68 |  | 114d |  |
| 70 |  | Build | 2d | 2002-05-27 | 2002-05-28 | 69 |  | 114d |  |
| 71 |  | Test | 1d | 2002-05-29 | 2002-05-29 | 70 |  | 114d |  |
| 72 | 1.4.1.6 | **RF Modem** | 44d | 2002-03-15 A | 2002-05-15 |  | 71% | 134d |  |
| 73 |  | Evaluate Data-link vs Freewave | 5d | 2002-03-15 A | 2002-03-21 A |  | 100% |  |  |
| 74 |  | Purchase | 2d | 2002-05-14 | 2002-05-15 |  |  | 134d | start no earlier than 2002-05-14 |

| ID | WBS | Task | Duration | Start | Finish | Predecessors | Complete | Total float | Constraint |
| --- | --- | --- | --- | --- | --- | --- | --- | --- | --- |
| 75 | 1.4.1.7 | **Acoustic Modem** | 2d | 2002-05-17 | 2002-05-20 |  |  | 121d |  |
| 76 |  | Evaluate | 1d | 2002-05-17 | 2002-05-17 |  |  | 121d | start no earlier than 2002-05-17 |
| 77 |  | Purchase | 1d | 2002-05-20 | 2002-05-20 | 76 |  | 121d |  |
| 78 | 1.4.1.8 | **GPS** | 15d | 2002-05-16 | 2002-06-05 |  |  | 109d |  |
| 79 |  | Evaluate GPS Position Fix Problem | 10d | 2002-05-16 | 2002-05-29 |  |  | 109d | start no earlier than 2002-05-16 |
| 80 |  | Evaluate GPS Board & Antennae | 4d | 2002-05-30 | 2002-06-04 | 79 |  | 109d |  |
| 81 |  | Purchase GPS Board & Antennae | 1d | 2002-06-05 | 2002-06-05 | 80 |  | 109d |  |
| 82 |  | Eval and Purchase 10/100 Hub | 4d | 2002-03-20 A | 2002-03-25 A |  | 100% |  | start no earlier than 2002-03-20 |
| 83 |  | Eval & Purchase AHRS | 1d | 2002-03-15 A | 2002-03-15 A |  | 100% |  |  |
| 84 |  | Eval and Purchase LBL Board Set | 4d | 2002-03-15 A | 2002-03-20 A |  | 100% |  |  |
| 85 |  | Spec and Purcahse DVL | 5d | 2002-05-14 A | 2002-05-20 |  | 80% | 131d |  |
| 86 | 1.4.2 | **MVC Housing** | 58d | 2002-03-15 A | 2002-06-04 |  | 17% | 110d |  |
| 87 |  | Spec Interconnects | 6d | 2002-03-15 A | 2002-03-22 |  | 80% | 140d |  |
| 88 |  | Design | 5d | 2002-05-06 | 2002-05-10 | 87 |  | 110d | start no earlier than 2002-05-04 |
| 89 |  | Build/Purchase | 10d | 2002-05-13 | 2002-05-24 | 88 |  | 110d |  |
| 90 |  | Pressure Test | 2d | 2002-05-27 | 2002-05-28 | 89 |  | 110d |  |
| 91 |  | Electronics Packagin Layout | 5d | 2002-05-29 | 2002-06-04 | 90 |  | 110d |  |
| 92 | 1.4.3 | **Documentation Package** | 11d | 2002-09-05 | 2002-09-19 | 91, 78, 75, 66 |  | 43d |  |
| 93 |  | Mechanical | 2d | 2002-09-05 | 2002-09-06 |  |  | 50d | start no earlier than 2002-09-05 |
| 94 |  | Electrical | 8d | 2002-09-05 | 2002-09-16 |  |  | 44d | start no earlier than 2002-09-05 |
| 95 |  | Software | 2d | 2002-09-16 | 2002-09-17 |  |  | 43d | start no earlier than 2002-09-16 |
| 96 |  | Integration | 2d | 2002-09-18 | 2002-09-19 | 94, 95, 93 |  | 43d | start no earlier than 2002-07-25 |
| 98 | 1.5 | **Navigation Hardware & Testing** | 53d | 2002-09-02 A | 2002-11-13 |  | 2% | 4d |  |
| 99 | 1.5.1 | **Deep Water testing of USBL** | 38d | 2002-09-02 | 2002-10-23 |  |  | 4d |  |
| 100 |  | Tank testing | 18d | 2002-09-02 | 2002-09-25 |  |  | 4d | start no earlier than 2002-09-01 |
| 101 |  | At Sea Testing | 20d | 2002-09-26 | 2002-10-23 | 100 |  | 4d |  |
| 102 | 1.5.2 | **Deep Water Testing of LBL Fish Mode** | 15d | 2002-10-24 | 2002-11-13 | 99 |  | 4d |  |
| 103 |  | Tank Testing | 10d | 2002-10-24 | 2002-11-06 |  |  | 4d | start no earlier than 2002-09-09 |
| 104 |  | At Sea Testing | 5d | 2002-11-07 | 2002-11-13 | 103 |  | 4d |  |
| 105 |  | Radio Range for modems | 3d | 2002-09-06 | 2002-09-10 |  |  | 50d | start no earlier than 2002-09-06 |
| 106 |  | RDF Ranging | 3d | 2002-09-09 | 2002-09-11 |  |  | 48d | start no earlier than 2002-09-07 |
| 107 |  | Eval Zephyr RDF capability | 1d | 2002-09-12 A | 2002-09-12 A | 106 | 100% |  |  |
| 109 | 1.6 | **Fairings / Vehicle Mechanical Structure** | 81d | 2002-03-15 A | 2002-07-05 |  | 5% | 97d |  |
| 110 | 1.6.1 | **L&R System Interface** | 81d | 2002-03-15 A | 2002-07-05 |  | 18% | 97d |  |
| 111 |  | Prelim Concept w/ Brook ocean | 5d | 2002-03-15 A | 2002-03-21 A |  | 100% |  |  |
| 112 |  | Concept Design Review / Decision | 5.5d | 2002-03-22 A | 2002-05-24 | 111 | 9% | 127d |  |
| 113 |  | Design L&R Interface | 10d | 2002-05-27 | 2002-06-07 |  |  | 97d | start no earlier than 2002-05-27 |
| 114 |  | Build Interface | 10d | 2002-06-10 | 2002-06-21 | 113 |  | 97d |  |
| 115 |  | Assemble Interface | 5d | 2002-06-24 | 2002-06-28 | 114 |  | 97d |  |
| 116 |  | L&R test plan | 4d | 2002-05-27 | 2002-05-30 |  |  | 118d | start no earlier than 2002-05-26 |
| 117 |  | Integrate and Test L&R Interface | 5d | 2002-07-01 | 2002-07-05 | 116, 115 |  | 97d |  |
| 118 |  | Evaluate Single Point lift | 3d | 2002-05-06 A | 2002-05-08 A |  | 100% |  | start no earlier than 2002-05-04 |
| 119 | 1.6.2 | **Joining Ring/Systems** | 37d | 2002-05-10 | 2002-07-01 |  |  | 101d |  |
| 120 |  | Evaluate joining ring systems | 2d | 2002-05-10 | 2002-05-13 |  |  | 86d | start no earlier than 2002-05-10 |
| 121 |  | Review Concept | 1d | 2002-05-14 | 2002-05-14 | 120 |  | 86d |  |
| 122 |  | Final Design | 15d | 2002-05-15 | 2002-06-04 | 121 |  | 86d |  |
| 123 |  | Build | 10d | 2002-06-05 | 2002-06-18 | 122 |  | 86d |  |
| 124 |  | Assemble | 3d | 2002-06-19 | 2002-06-21 | 123 |  | 86d |  |
| 125 |  | Test | 3d | 2002-06-24 | 2002-06-26 | 124 |  | 86d |  |
| 126 |  | Test new joining ring system | 3d | 2002-06-27 | 2002-07-01 |  |  | 83d | start no earlier than 2002-06-27 |
| 127 | 1.6.3 | **Deck Handling Equipment** | 15d | 2002-05-20 | 2002-06-07 |  |  | 117d |  |
| 128 |  | New Cart Design | 5d | 2002-05-20 | 2002-05-24 |  |  | 127d | start no earlier than 2002-05-19 |
| 129 |  | New Lifitng Gear | 5d | 2002-05-27 | 2002-05-31 |  |  | 122d | start no earlier than 2002-05-25 |
| 130 |  | Sphere Lift Mechanism | 10d | 2002-05-21 | 2002-06-03 |  |  | 121d | start no earlier than 2002-05-21 |
| 131 |  | Eval Single Pt. Lift | 2d | 2002-05-23 | 2002-05-24 |  |  | 127d | start no earlier than 2002-05-23 |
| 132 |  | Lifting I beam in Lab | 5d | 2002-05-30 | 2002-06-05 |  |  | 119d | start no earlier than 2002-05-30 |
| 133 |  | Cable trays nad outlets in lab ceiling | 5d | 2002-06-03 | 2002-06-07 |  |  | 117d | start no earlier than 2002-06-03 |
| 134 | 1.6.4 | **Sensor & Payload Mounts** | 7d | 2002-05-20 | 2002-05-28 |  |  | 117d |  |
| 135 |  | Antennaes | 5d | 2002-05-20 | 2002-05-24 |  |  | 109d | start no earlier than 2002-05-18 |
| 136 |  | ORE & various equip | 4d | 2002-05-23 | 2002-05-28 |  |  | 107d | start no earlier than 2002-05-23 |
| 137 | 1.6.5 | **Buoyancy** | 10d | 2002-05-22 | 2002-06-04 |  |  | 112d |  |
| 138 |  | Tailcone Foam Pack Specification | 5d | 2002-05-22 | 2002-05-28 |  |  | 102d | start no earlier than 2002-05-22 |
| 139 |  | Tailcone foam machining | 5d | 2002-05-29 | 2002-06-04 | 138 |  | 102d |  |
| 140 |  | Modular trim / ballast systems concept | 5d | 2002-05-22 | 2002-05-28 |  |  | 107d | start no earlier than 2002-05-22 |
| 141 | 1.6.6 | **Fairing Build** | 13d | 2002-06-10 | 2002-06-26 | 134, 137 |  | 104d |  |
| 142 |  | Noes section (2 plus 1 spare) | 8d | 2002-06-10 | 2002-06-19 |  |  | 109d | start no earlier than 2002-06-10 |
| 143 |  | Midboady (2 plus 1 spare) | 8d | 2002-06-13 | 2002-06-24 |  |  | 106d | start no earlier than 2002-06-13 |
| 144 |  | Tail section (2 plus 1 spare) | 8d | 2002-06-17 | 2002-06-26 |  |  | 104d | start no earlier than 2002-06-17 |
| 146 | 1.7 | **Software** | 107d | 2002-06-24 | 2002-11-19 |  |  | 0d |  |
| 147 |  | Change supervisor so drivers run all the time | 3d | 2002-09-02 | 2002-09-04 |  |  | 50d | start no earlier than 2002-09-02 |

| ID | WBS | Task | Duration | Start | Finish | Predecessors | Total float | Constraint |
| --- | --- | --- | --- | --- | --- | --- | --- | --- |
| 148 |  | Chang logging to convert files to MATLAB | 4d | 2002-09-05 | 2002-09-10 | 147 | 50d |  |
| 149 | 1.7.3 | **OS Upgrade** | 6d | 2002-09-12 | 2002-09-19 |  | 43d |  |
| 150 |  | QNX Upgrade to Neutrino | 3d | 2002-09-12 | 2002-09-16 |  | 43d | start no earlier than 2002-09-12 |
| 151 |  | Eval Linux for possible upgrade in future | 3d | 2002-09-17 | 2002-09-19 | 150 | 43d |  |
| 152 | 1.7.4 | **GUI** | 50d | 2002-07-02 | 2002-09-09 |  | 51d |  |
| 153 |  | gather requirements | 5d | 2002-07-02 | 2002-07-08 |  | 51d | start no earlier than 2002-07-02 |
| 154 |  | eval Bluefin GUI | 10d | 2002-07-09 | 2002-07-22 | 153 | 51d |  |
| 155 |  | develop GUI plan | 5d | 2002-07-23 | 2002-07-29 | 154 | 51d |  |
| 156 |  | Detail GUI development (TBD) | 30d | 2002-07-30 | 2002-09-09 | 155 | 51d |  |
| 157 |  | Configuration management on vehicle (config files) | 15d | 2002-08-16 | 2002-09-05 |  | 53d | start no earlier than 2002-08-16 |
| 158 | 1.7.6 | **Controls** | 45d | 2002-06-24 | 2002-08-23 |  | 62d |  |
| 159 |  | depth control improvement (long configs) | 15d | 2002-06-24 | 2002-07-12 |  | 62d | start no earlier than 2002-06-22 |
| 160 |  | sway / yaw control coupling (heave/ pitch too) | 10d | 2002-07-15 | 2002-07-26 | 159 | 62d |  |
| 161 |  | slow speed dynamics for control | 20d | 2002-07-29 | 2002-08-23 | 160 | 62d |  |
| 162 | 1.7.7 | **Navigation Software** | 42d | 2002-09-23 | 2002-11-19 |  | 0d |  |
| 163 |  | Document current NAV sys | 4d | 2002-09-23 | 2002-09-26 |  | 0d | start no earlier than 2002-09-23 |
| 164 |  | Streamline current nav architecture | 8d | 2002-09-27 | 2002-10-08 | 163 | 0d |  |
| 165 |  | Single beacon homing | 15d | 2002-10-09 | 2002-10-29 | 164 | 0d |  |
| 166 |  | Single beacon LBL | 15d | 2002-10-30 | 2002-11-19 | 165 | 0d |  |
| 167 |  | DVL driver enhancements for PD5 | 15d | 2002-10-09 | 2002-10-29 | 164 | 15d |  |
| 168 | 1.7.8 | **Intra-vehicle Comms** | 4d | 2002-10-01 | 2002-10-04 |  | 32d |  |
| 169 |  | set up socket code (for reconnects) | 3d | 2002-10-01 | 2002-10-03 |  | 32d | start no earlier than 2002-10-01 |
| 170 |  | briding over wireless | 1d | 2002-10-04 | 2002-10-04 | 169 | 32d |  |
| 172 | 1.8 | **Vehicle Integration and Test** | 40d | 2002-06-10 | 2002-08-02 |  | 76d |  |
| 173 |  | Tailcone Assembly | 5d | 2002-06-10 | 2002-06-14 |  | 86d | start no earlier than 2002-06-08 |
| 174 |  | Tailcone Test | 4d | 2002-06-17 | 2002-06-20 | 173 | 86d |  |
| 175 |  | Battery Midbody Integration | 5d | 2002-06-17 | 2002-06-21 |  | 81d | start no earlier than 2002-06-17 |
| 176 |  | Battery Midbody Test | 4d | 2002-06-24 | 2002-06-27 | 175 | 81d |  |
| 177 |  | ALTEX Nose Payload Assembly/Upgrade | 5d | 2002-06-17 | 2002-06-21 |  | 76d | start no earlier than 2002-06-17 |
| 178 |  | Science Payload Assembly | 6d | 2002-06-24 | 2002-07-01 | 177 | 76d | start no earlier than 2002-06-07 |
| 179 |  | Payload Test | 3d | 2002-07-02 | 2002-07-04 | 178 | 76d |  |
| 180 |  | Integrated Vehcile Deck Assembly | 2d | 2002-07-05 | 2002-07-08 | 174, 176, 179 | 76d |  |
| 181 |  | Vehicle Ballasting | 1d | 2002-07-09 | 2002-07-09 | 180 | 76d |  |
| 182 |  | Integrated Vehicle Deck Test | 3d | 2002-07-10 | 2002-07-12 | 181 | 76d |  |
| 183 |  | Integrated Vehicle Tank Test | 5d | 2002-07-15 | 2002-07-19 | 182 | 76d |  |
| 184 |  | Integrated Vehicle Sea Trials | 10d | 2002-07-22 | 2002-08-02 | 183 | 76d |  |
| 186 | 1.9 | **CTD Science Payload Core** | 33d? | 2002-06-20 | 2002-08-05 |  | 76d |  |
| 187 |  | Repair/Replace nose fairing | 3d | 2002-06-20 | 2002-06-24 |  | 157d | start no earlier than 2002-06-20 |
| 188 |  | recable Dcon to comms and pwr bus | 8d | 2002-06-21 | 2002-07-02 |  | 132d | start no earlier than 2002-06-21 |
| 189 |  | Design HS2 Mount | 2d | 2002-06-25 | 2002-06-26 | 187 | 157d |  |
| 190 |  | Build HS2 Mount | 2d | 2002-06-27 | 2002-06-28 | 189 | 157d |  |
| 191 |  | Assembly HS2 Mount | 2d | 2002-07-01 | 2002-07-02 | 190 | 157d |  |
| 192 |  | Write test driver HS2 | 5d | 2002-06-27 | 2002-07-03 |  | 156d | start no earlier than 2002-06-27 |
| 193 |  | Eval Foam buoyancy cooridnate 1500 M version | 5d | 2002-06-28 | 2002-07-04 |  | 155d | start no earlier than 2002-06-28 |
| 194 |  | repair flow sensor #2 | 3d | 2002-07-03 | 2002-07-05 | 188 | 132d |  |
| 195 |  | test integrated CTD Payload | 1d? | 2002-08-05 | 2002-08-05 | 194, 172 | 76d |  |
| 197 | 1.10 | **CTD Extension for Ryan/Haddock** | 21d | 2002-06-03 | 2002-07-01 |  | 101d |  |
| 198 |  | Design LISST pump assy | 4d | 2002-06-03 | 2002-06-06 |  | 101d | start no earlier than 2002-06-03 |
| 199 |  | Fab LISST pump assy | 5d | 2002-06-07 | 2002-06-13 | 198 | 104d |  |
| 200 |  | Assy LISST pump into vehicle | 2d | 2002-06-14 | 2002-06-17 | 199 | 104d |  |
| 201 |  | Design LISST mount | 5d | 2002-06-07 | 2002-06-13 | 198 | 101d |  |
| 202 |  | Fab LISST Mount | 5d | 2002-06-14 | 2002-06-20 | 201 | 101d |  |
| 203 |  | Assy LISST mount | 2d | 2002-06-21 | 2002-06-24 | 200, 202 | 101d |  |
| 204 |  | Cable LISST to Dcon | 1d | 2002-06-25 | 2002-06-25 | 203 | 105d |  |
| 205 |  | Write Test Driver for LISST | 5d | 2002-06-25 | 2002-07-01 | 203 | 101d |  |
| 206 |  | Design Bathypho mount | 4d | 2002-06-05 | 2002-06-10 |  | 105d | start no earlier than 2002-06-05 |
| 207 |  | Fab Bathypho mount | 5d | 2002-06-11 | 2002-06-17 | 206 | 105d |  |
| 208 |  | Assy Bathypho mount | 2d | 2002-06-18 | 2002-06-19 | 207 | 105d |  |
| 209 |  | Cable Bathypho to Dcon | 1d | 2002-06-20 | 2002-06-20 | 208 | 105d |  |
| 210 |  | Retest driver for Bathypho (already written) | 3d | 2002-06-21 | 2002-06-25 | 209 | 105d |  |
| 212 |  | Ryan / Haddock Cruise Prep | 14d | 2002-07-29 | 2002-08-15 |  | 68d | start no earlier than 2002-07-27 |

## Version 2 (saved 2002-06-03, file Dorado2002revD.mpp)

Last finish stays 2002-11-19.

Added:

| ID | Task | Duration | Start | Finish | Constraint | Resources |
| --- | --- | --- | --- | --- | --- | --- |
| 14 | Replace foam with 4500 M | 20d | 2002-06-17 | 2002-07-12 | start no earlier than 2002-06-17 | Drew [15%] |
| 15 | Compensator design / purchase | 1d? | 2002-03-15 | 2002-03-15 |  |  |

Changed:

| ID | Task | Start | Finish | Duration | Complete | Total float | Other |
| --- | --- | --- | --- | --- | --- | --- | --- |
| 1 | **Dorado Program** |  |  |  | 8% → 9% |  | baseline start none → 2002-03-15; baseline finish none → 2002-11-19 |
| 3 | **Propulsion** | 2002-05-02 A → 2002-03-15 A (-48d) |  | 99d → 133d? | 1% → 12% |  | baseline start none → 2002-05-02; baseline finish none → 2002-09-17 |
| 4 | **Articulated Tail** | 2002-05-02 → 2002-05-20 A (+18d) |  | 95d → 83d | 0% → 38% |  | baseline start none → 2002-05-02; baseline finish none → 2002-09-11 |
| 5 | Design & Build New Electronics Housing | 2002-05-02 → 2002-05-20 A (+18d) | 2002-05-15 → 2002-06-19 (+35d) | 10d → 23d | 0% → 50% | 130d → 105d | baseline start none → 2002-05-02; baseline finish none → 2002-05-15 |
| 6 | New Linear Actuator Scheme |  |  |  |  |  | baseline start none → 2002-09-03; baseline finish none → 2002-09-11 |
| 7 | **Drive Electronics** | 2002-05-06 → 2002-05-27 A (+21d) | 2002-06-06 → 2002-07-22 (+46d) | 24d → 41d |  | 113d → 81d | baseline start none → 2002-05-06; baseline finish none → 2002-06-06 |
| 8 | Integrate New Electroincs | 2002-05-06 → 2002-06-19 A (+44d) | 2002-06-06 → 2002-07-22 (+46d) |  |  | 112d → 81d | baseline start none → 2002-05-06; baseline finish none → 2002-06-06 |
| 9 | Cabling |  |  |  |  | 116d → 117d | baseline start none → 2002-05-27; baseline finish none → 2002-05-31 |
| 10 | Integrate New Tail Into fairing | 2002-06-07 → 2002-07-23 (+46d) | 2002-06-13 → 2002-07-29 (+46d) |  |  | 112d → 81d | baseline start none → 2002-06-07; baseline finish none → 2002-06-13 |
| 11 | Tailcone - Bench Stand Design and Fab |  |  |  |  |  | baseline start none → 2002-05-27; baseline finish none → 2002-05-29 |
| 12 | Buoyancy Check / Test |  |  |  |  |  | baseline start none → 2002-06-14; baseline finish none → 2002-06-14 |
| 13 | Test Plan |  |  |  |  |  | baseline start none → 2002-06-14; baseline finish none → 2002-06-20 |
| 16 | **Tailcone Documetation** |  |  |  |  |  | baseline start none → 2002-09-12; baseline finish none → 2002-09-17 |
| 17 | Mechanical |  |  |  |  |  | baseline start none → 2002-09-12; baseline finish none → 2002-09-16 |
| 18 | Electrical |  |  |  |  |  | baseline start none → 2002-09-12; baseline finish none → 2002-09-13 |
| 19 | Software |  |  |  |  |  | baseline start none → 2002-09-12; baseline finish none → 2002-09-17 |
| 21 | **Power** |  |  |  |  | 163d → 106d | baseline start none → 2002-04-15; baseline finish none → 2002-06-24 |
| 22 | **Battery Chemistry** |  |  |  |  | 182d → 125d | baseline start none → 2002-04-15; baseline finish none → 2002-05-23 |
| 23 | Check life on current Ag-Zn batteries |  |  |  |  | 119d → 122d | baseline start none → 2002-04-15; baseline finish none → 2002-04-18 |
| 24 | Trade study to review Batt Chems |  |  |  |  | 117d → 120d | baseline start none → 2002-04-18; baseline finish none → 2002-04-22 |
| 25 | Thermal Analysis of Battery Pack |  |  |  |  | 116d → 119d | baseline start none → 2002-04-17; baseline finish none → 2002-04-23 |
| 26 | Design Review of Batt Chems |  |  |  |  | 116d → 119d | baseline start none → 2002-04-24; baseline finish none → 2002-04-24 |
| 27 | Purchase Batteries |  |  |  |  | 182d → 125d | baseline start none → 2002-04-25; baseline finish none → 2002-04-25 |
| 28 | Assemble Batteries |  |  |  |  | 182d → 125d | baseline start none → 2002-04-26; baseline finish none → 2002-05-02 |
| 29 | Test Batteries |  |  |  |  | 182d → 125d | baseline start none → 2002-05-03; baseline finish none → 2002-05-23 |
| 30 | **Battery Housing** |  |  |  |  | 172d → 115d | baseline start none → 2002-04-25; baseline finish none → 2002-06-11 |
| 31 | Design |  |  |  |  | 172d → 115d | baseline start none → 2002-05-01; baseline finish none → 2002-05-14 |
| 32 | Build |  |  |  |  | 172d → 115d | baseline start none → 2002-05-15; baseline finish none → 2002-06-04 |
| 33 | Test |  |  |  |  | 172d → 115d | baseline start none → 2002-06-05; baseline finish none → 2002-06-11 |
| 34 | Spec Interconnects |  |  |  |  |  | baseline start none → 2002-04-25; baseline finish none → 2002-04-30 |
| 35 | **Battery Electronics** |  |  |  |  | 171d → 114d | baseline start none → 2002-05-01; baseline finish none → 2002-06-10 |
| 36 | Concept Design |  |  |  |  | 179d → 122d | baseline start none → 2002-05-01; baseline finish none → 2002-05-07 |
| 37 | Design Review |  |  |  |  | 179d → 122d | baseline start none → 2002-05-08; baseline finish none → 2002-05-09 |
| 38 | Final Design |  |  |  |  | 179d → 122d | baseline start none → 2002-05-10; baseline finish none → 2002-05-24 |
| 39 | Build |  |  |  |  | 179d → 122d | baseline start none → 2002-05-27; baseline finish none → 2002-05-27 |
| 40 | Assemble |  |  |  |  | 179d → 122d | baseline start none → 2002-05-28; baseline finish none → 2002-05-28 |
| 41 | Test |  |  |  |  | 179d → 122d | baseline start none → 2002-05-29; baseline finish none → 2002-05-29 |
| 42 | Spec Misc Electronics (Contingency) |  |  |  |  | 171d → 114d | baseline start none → 2002-06-10; baseline finish none → 2002-06-10 |
| 43 | **Battery Charging** |  |  |  |  | 171d → 114d | baseline start none → 2002-06-11; baseline finish none → 2002-06-12 |
| 44 | Spec Charging Analysis |  |  |  |  | 171d → 114d | baseline start none → 2002-06-11; baseline finish none → 2002-06-12 |
| 45 | Order Charging Equip as Required |  |  |  |  | 172d → 115d | baseline start none → 2002-06-11; baseline finish none → 2002-06-11 |
| 46 | AUV Power Systems Meeting |  |  |  |  | 163d → 106d | baseline start none → 2002-06-19; baseline finish none → 2002-06-24 |
| 48 | **Cabling and Connectors** |  |  |  |  |  | baseline start none → 2002-04-25; baseline finish none → 2002-06-21 |
| 49 | Spec Main Power / Comms Cable&Connectors/Penetrators |  |  |  |  |  | baseline start none → 2002-04-25; baseline finish none → 2002-05-13 |
| 50 | Spec Charging Connector |  |  |  |  |  | baseline start none → 2002-05-14; baseline finish none → 2002-05-17 |
| 51 | Spec Tailcone Comms Cable&Connector/Penetrator |  |  |  |  |  | baseline start none → 2002-04-25; baseline finish none → 2002-04-29 |
| 52 | Spec Science Instrument Connector |  |  |  |  |  | baseline start none → 2002-04-25; baseline finish none → 2002-04-26 |
| 53 | Spec DVL and parosci Connectors / Penetrator |  |  |  |  |  | baseline start none → 2002-04-29; baseline finish none → 2002-04-29 |
| 54 | Spec RF/Acoustic/Emer location Connect & Penetrators |  |  |  |  |  | baseline start none → 2002-04-30; baseline finish none → 2002-04-30 |
| 55 | Spec On/Off Connector/Penetrator |  |  |  |  |  | baseline start none → 2002-05-01; baseline finish none → 2002-05-01 |
| 56 | Test ability of 100 MB/s thrugh current ALTEX Cable |  |  |  |  |  | baseline start none → 2002-05-21; baseline finish none → 2002-05-22 |
| 57 | Order Connectors |  |  |  |  |  | baseline start none → 2002-05-14; baseline finish none → 2002-05-15 |
| 58 | **Tail to MVC** |  |  |  |  |  | baseline start none → 2002-05-09; baseline finish none → 2002-05-09 |
| 59 | Section Interconnect |  |  |  |  |  | baseline start none → 2002-05-09; baseline finish none → 2002-05-09 |
| 60 | Documetation package on Connectors and Cabling |  |  |  |  |  | baseline start none → 2002-06-10; baseline finish none → 2002-06-21 |
| 62 | **Main Vehicle Computer** |  |  |  |  |  | baseline start none → 2002-03-15; baseline finish none → 2002-09-19 |
| 63 | **Electronics** |  |  |  |  |  | baseline start none → 2002-03-15; baseline finish none → 2002-06-05 |
| 64 | Spec PC 104 Stack |  |  |  |  |  | baseline start none → 2002-03-15; baseline finish none → 2002-03-18 |
| 65 | Order PC 104 Stack |  |  |  |  |  | baseline start none → 2002-03-19; baseline finish none → 2002-05-07 |
| 66 | Assemble PC 104 Stack |  |  |  |  |  | baseline start none → 2002-05-07; baseline finish none → 2002-05-09 |
| 67 | Develop latency test/budget for MVC |  |  |  |  |  | baseline start none → 2002-05-13; baseline finish none → 2002-05-16 |
| 68 | **Power Board** |  |  |  |  |  | baseline start none → 2002-04-28; baseline finish none → 2002-05-29 |
| 69 | Specify |  |  |  |  |  | baseline start none → 2002-04-28; baseline finish none → 2002-05-02 |
| 70 | Design |  |  |  |  |  | baseline start none → 2002-05-03; baseline finish none → 2002-05-23 |
| 71 | Order |  |  |  |  |  | baseline start none → 2002-05-24; baseline finish none → 2002-05-24 |
| 72 | Build |  |  |  |  |  | baseline start none → 2002-05-27; baseline finish none → 2002-05-28 |
| 73 | Test |  |  |  |  |  | baseline start none → 2002-05-29; baseline finish none → 2002-05-29 |
| 74 | **RF Modem** |  |  |  |  |  | baseline start none → 2002-03-15; baseline finish none → 2002-05-15 |
| 75 | Evaluate Data-link vs Freewave |  |  |  |  |  | baseline start none → 2002-03-15; baseline finish none → 2002-03-21 |
| 76 | Purchase |  |  |  |  |  | baseline start none → 2002-05-14; baseline finish none → 2002-05-15 |

| ID | Task | Total float | Other |
| --- | --- | --- | --- |
| 77 | **Acoustic Modem** |  | baseline start none → 2002-05-17; baseline finish none → 2002-05-20 |
| 78 | Evaluate |  | baseline start none → 2002-05-17; baseline finish none → 2002-05-17 |
| 79 | Purchase |  | baseline start none → 2002-05-20; baseline finish none → 2002-05-20 |
| 80 | **GPS** |  | baseline start none → 2002-05-16; baseline finish none → 2002-06-05 |
| 81 | Evaluate GPS Position Fix Problem |  | baseline start none → 2002-05-16; baseline finish none → 2002-05-29 |
| 82 | Evaluate GPS Board & Antennae |  | baseline start none → 2002-05-30; baseline finish none → 2002-06-04 |
| 83 | Purchase GPS Board & Antennae |  | baseline start none → 2002-06-05; baseline finish none → 2002-06-05 |
| 84 | Eval and Purchase 10/100 Hub |  | baseline start none → 2002-03-20; baseline finish none → 2002-03-25 |
| 85 | Eval & Purchase AHRS |  | baseline start none → 2002-03-15; baseline finish none → 2002-03-15 |
| 86 | Eval and Purchase LBL Board Set |  | baseline start none → 2002-03-15; baseline finish none → 2002-03-20 |
| 87 | Spec and Purcahse DVL |  | baseline start none → 2002-05-14; baseline finish none → 2002-05-20 |
| 88 | **MVC Housing** |  | baseline start none → 2002-03-15; baseline finish none → 2002-06-04 |
| 89 | Spec Interconnects |  | baseline start none → 2002-03-15; baseline finish none → 2002-03-22 |
| 90 | Design |  | baseline start none → 2002-05-06; baseline finish none → 2002-05-10 |
| 91 | Build/Purchase |  | baseline start none → 2002-05-13; baseline finish none → 2002-05-24 |
| 92 | Pressure Test |  | baseline start none → 2002-05-27; baseline finish none → 2002-05-28 |
| 93 | Electronics Packagin Layout |  | baseline start none → 2002-05-29; baseline finish none → 2002-06-04 |
| 94 | **Documentation Package** |  | baseline start none → 2002-09-05; baseline finish none → 2002-09-19 |
| 95 | Mechanical |  | baseline start none → 2002-09-05; baseline finish none → 2002-09-06 |
| 96 | Electrical |  | baseline start none → 2002-09-05; baseline finish none → 2002-09-16 |
| 97 | Software |  | baseline start none → 2002-09-16; baseline finish none → 2002-09-17 |
| 98 | Integration |  | baseline start none → 2002-09-18; baseline finish none → 2002-09-19 |
| 100 | **Navigation Hardware & Testing** |  | baseline start none → 2002-09-02; baseline finish none → 2002-11-13 |
| 101 | **Deep Water testing of USBL** |  | baseline start none → 2002-09-02; baseline finish none → 2002-10-23 |
| 102 | Tank testing |  | baseline start none → 2002-09-02; baseline finish none → 2002-09-25 |
| 103 | At Sea Testing |  | baseline start none → 2002-09-26; baseline finish none → 2002-10-23 |
| 104 | **Deep Water Testing of LBL Fish Mode** |  | baseline start none → 2002-10-24; baseline finish none → 2002-11-13 |
| 105 | Tank Testing |  | baseline start none → 2002-10-24; baseline finish none → 2002-11-06 |
| 106 | At Sea Testing |  | baseline start none → 2002-11-07; baseline finish none → 2002-11-13 |
| 107 | Radio Range for modems |  | baseline start none → 2002-09-06; baseline finish none → 2002-09-10 |
| 108 | RDF Ranging | 48d → 49d | baseline start none → 2002-09-09; baseline finish none → 2002-09-11 |
| 109 | Eval Zephyr RDF capability |  | baseline start none → 2002-09-12; baseline finish none → 2002-09-12 |
| 111 | **Fairings / Vehicle Mechanical Structure** |  | baseline start none → 2002-03-15; baseline finish none → 2002-07-05 |
| 112 | **L&R System Interface** |  | baseline start none → 2002-03-15; baseline finish none → 2002-07-05 |
| 113 | Prelim Concept w/ Brook ocean |  | baseline start none → 2002-03-15; baseline finish none → 2002-03-21 |
| 114 | Concept Design Review / Decision |  | baseline start none → 2002-03-22; baseline finish none → 2002-05-24 |
| 115 | Design L&R Interface |  | baseline start none → 2002-05-27; baseline finish none → 2002-06-07 |
| 116 | Build Interface |  | baseline start none → 2002-06-10; baseline finish none → 2002-06-21 |
| 117 | Assemble Interface |  | baseline start none → 2002-06-24; baseline finish none → 2002-06-28 |
| 118 | L&R test plan |  | baseline start none → 2002-05-27; baseline finish none → 2002-05-30 |
| 119 | Integrate and Test L&R Interface |  | baseline start none → 2002-07-01; baseline finish none → 2002-07-05 |
| 120 | Evaluate Single Point lift |  | baseline start none → 2002-05-06; baseline finish none → 2002-05-08 |
| 121 | **Joining Ring/Systems** |  | baseline start none → 2002-05-10; baseline finish none → 2002-07-01 |
| 122 | Evaluate joining ring systems | 86d → 104d | baseline start none → 2002-05-10; baseline finish none → 2002-05-13 |
| 123 | Review Concept | 86d → 104d | baseline start none → 2002-05-14; baseline finish none → 2002-05-14 |
| 124 | Final Design | 86d → 104d | baseline start none → 2002-05-15; baseline finish none → 2002-06-04 |
| 125 | Build | 86d → 104d | baseline start none → 2002-06-05; baseline finish none → 2002-06-18 |
| 126 | Assemble | 86d → 104d | baseline start none → 2002-06-19; baseline finish none → 2002-06-21 |
| 127 | Test | 86d → 104d | baseline start none → 2002-06-24; baseline finish none → 2002-06-26 |
| 128 | Test new joining ring system | 83d → 101d | baseline start none → 2002-06-27; baseline finish none → 2002-07-01 |
| 129 | **Deck Handling Equipment** |  | baseline start none → 2002-05-20; baseline finish none → 2002-06-07 |
| 130 | New Cart Design |  | baseline start none → 2002-05-20; baseline finish none → 2002-05-24 |
| 131 | New Lifitng Gear |  | baseline start none → 2002-05-27; baseline finish none → 2002-05-31 |
| 132 | Sphere Lift Mechanism |  | baseline start none → 2002-05-21; baseline finish none → 2002-06-03 |
| 133 | Eval Single Pt. Lift |  | baseline start none → 2002-05-23; baseline finish none → 2002-05-24 |
| 134 | Lifting I beam in Lab |  | baseline start none → 2002-05-30; baseline finish none → 2002-06-05 |
| 135 | Cable trays nad outlets in lab ceiling |  | baseline start none → 2002-06-03; baseline finish none → 2002-06-07 |
| 136 | **Sensor & Payload Mounts** |  | baseline start none → 2002-05-20; baseline finish none → 2002-05-28 |
| 137 | Antennaes | 109d → 119d | baseline start none → 2002-05-20; baseline finish none → 2002-05-24 |
| 138 | ORE & various equip | 107d → 117d | baseline start none → 2002-05-23; baseline finish none → 2002-05-28 |
| 139 | **Buoyancy** |  | baseline start none → 2002-05-22; baseline finish none → 2002-06-04 |
| 140 | Tailcone Foam Pack Specification | 102d → 112d | baseline start none → 2002-05-22; baseline finish none → 2002-05-28 |
| 141 | Tailcone foam machining | 102d → 112d | baseline start none → 2002-05-29; baseline finish none → 2002-06-04 |
| 142 | Modular trim / ballast systems concept | 107d → 117d | baseline start none → 2002-05-22; baseline finish none → 2002-05-28 |
| 143 | **Fairing Build** |  | baseline start none → 2002-06-10; baseline finish none → 2002-06-26 |
| 144 | Noes section (2 plus 1 spare) |  | baseline start none → 2002-06-10; baseline finish none → 2002-06-19 |
| 145 | Midboady (2 plus 1 spare) |  | baseline start none → 2002-06-13; baseline finish none → 2002-06-24 |
| 146 | Tail section (2 plus 1 spare) |  | baseline start none → 2002-06-17; baseline finish none → 2002-06-26 |
| 148 | **Software** |  | baseline start none → 2002-06-24; baseline finish none → 2002-11-19 |
| 149 | Change supervisor so drivers run all the time |  | baseline start none → 2002-09-02; baseline finish none → 2002-09-04 |

| ID | Task | Total float | Other |
| --- | --- | --- | --- |
| 150 | Chang logging to convert files to MATLAB |  | baseline start none → 2002-09-05; baseline finish none → 2002-09-10 |
| 151 | **OS Upgrade** |  | baseline start none → 2002-09-12; baseline finish none → 2002-09-19 |
| 152 | QNX Upgrade to Neutrino |  | baseline start none → 2002-09-12; baseline finish none → 2002-09-16 |
| 153 | Eval Linux for possible upgrade in future |  | baseline start none → 2002-09-17; baseline finish none → 2002-09-19 |
| 154 | **GUI** |  | baseline start none → 2002-07-02; baseline finish none → 2002-09-09 |
| 155 | gather requirements |  | baseline start none → 2002-07-02; baseline finish none → 2002-07-08 |
| 156 | eval Bluefin GUI |  | baseline start none → 2002-07-09; baseline finish none → 2002-07-22 |
| 157 | develop GUI plan |  | baseline start none → 2002-07-23; baseline finish none → 2002-07-29 |
| 158 | Detail GUI development (TBD) |  | baseline start none → 2002-07-30; baseline finish none → 2002-09-09 |
| 159 | Configuration management on vehicle (config files) |  | baseline start none → 2002-08-16; baseline finish none → 2002-09-05 |
| 160 | **Controls** |  | baseline start none → 2002-06-24; baseline finish none → 2002-08-23 |
| 161 | depth control improvement (long configs) |  | baseline start none → 2002-06-24; baseline finish none → 2002-07-12 |
| 162 | sway / yaw control coupling (heave/ pitch too) |  | baseline start none → 2002-07-15; baseline finish none → 2002-07-26 |
| 163 | slow speed dynamics for control |  | baseline start none → 2002-07-29; baseline finish none → 2002-08-23 |
| 164 | **Navigation Software** |  | baseline start none → 2002-09-23; baseline finish none → 2002-11-19 |
| 165 | Document current NAV sys |  | baseline start none → 2002-09-23; baseline finish none → 2002-09-26 |
| 166 | Streamline current nav architecture |  | baseline start none → 2002-09-27; baseline finish none → 2002-10-08 |
| 167 | Single beacon homing |  | baseline start none → 2002-10-09; baseline finish none → 2002-10-29 |
| 168 | Single beacon LBL |  | baseline start none → 2002-10-30; baseline finish none → 2002-11-19 |
| 169 | DVL driver enhancements for PD5 |  | baseline start none → 2002-10-09; baseline finish none → 2002-10-29 |
| 170 | **Intra-vehicle Comms** |  | baseline start none → 2002-10-01; baseline finish none → 2002-10-04 |
| 171 | set up socket code (for reconnects) |  | baseline start none → 2002-10-01; baseline finish none → 2002-10-03 |
| 172 | briding over wireless |  | baseline start none → 2002-10-04; baseline finish none → 2002-10-04 |
| 174 | **Vehicle Integration and Test** |  | baseline start none → 2002-06-10; baseline finish none → 2002-08-02 |
| 175 | Tailcone Assembly |  | baseline start none → 2002-06-10; baseline finish none → 2002-06-14 |
| 176 | Tailcone Test |  | baseline start none → 2002-06-17; baseline finish none → 2002-06-20 |
| 177 | Battery Midbody Integration |  | baseline start none → 2002-06-17; baseline finish none → 2002-06-21 |
| 178 | Battery Midbody Test |  | baseline start none → 2002-06-24; baseline finish none → 2002-06-27 |
| 179 | ALTEX Nose Payload Assembly/Upgrade |  | baseline start none → 2002-06-17; baseline finish none → 2002-06-21 |
| 180 | Science Payload Assembly |  | baseline start none → 2002-06-24; baseline finish none → 2002-07-01 |
| 181 | Payload Test |  | baseline start none → 2002-07-02; baseline finish none → 2002-07-04 |
| 182 | Integrated Vehcile Deck Assembly |  | baseline start none → 2002-07-05; baseline finish none → 2002-07-08 |
| 183 | Vehicle Ballasting |  | baseline start none → 2002-07-09; baseline finish none → 2002-07-09 |
| 184 | Integrated Vehicle Deck Test |  | baseline start none → 2002-07-10; baseline finish none → 2002-07-12 |
| 185 | Integrated Vehicle Tank Test |  | baseline start none → 2002-07-15; baseline finish none → 2002-07-19 |
| 186 | Integrated Vehicle Sea Trials |  | baseline start none → 2002-07-22; baseline finish none → 2002-08-02 |
| 188 | **CTD Science Payload Core** |  | baseline start none → 2002-06-20; baseline finish none → 2002-08-05 |
| 189 | Repair/Replace nose fairing | 157d → 100d | baseline start none → 2002-06-20; baseline finish none → 2002-06-24 |
| 190 | recable Dcon to comms and pwr bus | 132d → 96d | baseline start none → 2002-06-21; baseline finish none → 2002-07-02 |
| 191 | Design HS2 Mount | 157d → 100d | baseline start none → 2002-06-25; baseline finish none → 2002-06-26 |
| 192 | Build HS2 Mount | 157d → 100d | baseline start none → 2002-06-27; baseline finish none → 2002-06-28 |
| 193 | Assembly HS2 Mount | 157d → 100d | baseline start none → 2002-07-01; baseline finish none → 2002-07-02 |
| 194 | Write test driver HS2 | 156d → 99d | baseline start none → 2002-06-27; baseline finish none → 2002-07-03 |
| 195 | Eval Foam buoyancy cooridnate 1500 M version | 155d → 98d | baseline start none → 2002-06-28; baseline finish none → 2002-07-04 |
| 196 | repair flow sensor #2 | 132d → 96d | baseline start none → 2002-07-03; baseline finish none → 2002-07-05 |
| 197 | test integrated CTD Payload |  | baseline start none → 2002-08-05; baseline finish none → 2002-08-05 |
| 199 | **CTD Extension for Ryan/Haddock** |  | baseline start none → 2002-06-03; baseline finish none → 2002-07-01 |
| 200 | Design LISST pump assy |  | baseline start none → 2002-06-03; baseline finish none → 2002-06-06 |
| 201 | Fab LISST pump assy |  | baseline start none → 2002-06-07; baseline finish none → 2002-06-13 |
| 202 | Assy LISST pump into vehicle |  | baseline start none → 2002-06-14; baseline finish none → 2002-06-17 |
| 203 | Design LISST mount |  | baseline start none → 2002-06-07; baseline finish none → 2002-06-13 |
| 204 | Fab LISST Mount |  | baseline start none → 2002-06-14; baseline finish none → 2002-06-20 |
| 205 | Assy LISST mount |  | baseline start none → 2002-06-21; baseline finish none → 2002-06-24 |
| 206 | Cable LISST to Dcon |  | baseline start none → 2002-06-25; baseline finish none → 2002-06-25 |
| 207 | Write Test Driver for LISST |  | baseline start none → 2002-06-25; baseline finish none → 2002-07-01 |
| 208 | Design Bathypho mount |  | baseline start none → 2002-06-05; baseline finish none → 2002-06-10 |
| 209 | Fab Bathypho mount |  | baseline start none → 2002-06-11; baseline finish none → 2002-06-17 |
| 210 | Assy Bathypho mount |  | baseline start none → 2002-06-18; baseline finish none → 2002-06-19 |
| 211 | Cable Bathypho to Dcon |  | baseline start none → 2002-06-20; baseline finish none → 2002-06-20 |
| 212 | Retest driver for Bathypho (already written) |  | baseline start none → 2002-06-21; baseline finish none → 2002-06-25 |
| 214 | Ryan / Haddock Cruise Prep |  | baseline start none → 2002-07-29; baseline finish none → 2002-08-15 |

## Version 3 (data date 2002-06-03, saved 2002-06-06, file Dorado2002revE.mpp)

Last finish stays 2002-11-19. Complete tasks 16 → 27.

Added:

| ID | Task | Duration | Start | Finish | Predecessors | Constraint | Resources |
| --- | --- | --- | --- | --- | --- | --- | --- |
| 28 | Battery delivery | 40d? | 2002-06-14 | 2002-08-08 | 27 | start no earlier than 2002-06-14 |  |
| 62 | Cable Assy @ Seacon | 26d | 2002-06-18 | 2002-07-23 |  | start no earlier than 2002-06-18 | Seacon |

Changed:

| ID | Task | Start | Finish | Duration | Complete | Total float | Predecessors | Other |
| --- | --- | --- | --- | --- | --- | --- | --- | --- |
| 1 | **Dorado Program** |  |  |  | 9% → 15% |  |  |  |
| 3 | **Propulsion** | 2002-03-15 A → 2002-05-20 A (+66d) | 2002-09-17 → 2002-09-18 (+1d) | 133d? → 88d | 12% → 10% | 45d → 44d |  |  |
| 15 | Compensator Design/Purchase | 2002-03-15 → 2002-06-10 (+87d) | 2002-03-15 → 2002-07-05 (+112d) | 1d? → 20d |  | 177d → 97d |  | was named Compensator design / purchase; constraint none → start no earlier than 2002-06-10; resources none → Robert F |
| 16 | **Tailcone Documetation** |  | 2002-09-17 → 2002-09-18 (+1d) | 4d → 5d |  | 45d → 44d |  |  |
| 17 | Mechanical |  | 2002-09-16 → 2002-09-18 (+2d) | 3d → 5d |  | 46d → 44d |  | resources Farley → Farley; RobF |
| 21 | **Power** |  | 2002-06-24 → 2002-08-23 (+60d) | 51d? → 95d? | 9% → 10% | 106d → 62d |  |  |
| 22 | **Battery Chemistry** |  | 2002-05-23 → 2002-08-19 (+88d) | 29d → 91d? | 15% → 9% | 125d → 66d |  |  |
| 25 | Thermal Analysis of Battery Pack |  |  |  |  | 119d → 150d |  | resources Kiwi → Cancelled Task |
| 26 | Design Review of Batt Chems | 2002-04-24 → 2002-06-03 A (+40d) | 2002-04-24 → 2002-06-03 A (+40d) |  | 0% → 100% | 119d → none |  |  |
| 27 | Purchase Batteries | 2002-04-25 → 2002-06-04 (+40d) | 2002-04-25 → 2002-06-07 (+43d) | 1d → 4d |  | 125d → 66d |  |  |
| 29 | Assemble Batteries | 2002-04-26 → 2002-08-09 (+105d) | 2002-05-02 → 2002-08-14 (+104d) | 5d → 4d |  | 125d → 62d | 27 → 28 |  |
| 30 | Test Batteries | 2002-05-03 → 2002-08-15 (+104d) | 2002-05-23 → 2002-08-19 (+88d) | 15d → 3d |  | 125d → 62d |  |  |
| 31 | **Battery Housing** |  | 2002-06-11 → 2002-07-15 (+34d) | 34d → 58d |  | 115d → 91d |  |  |
| 32 | Design | 2002-05-01 → 2002-06-04 (+34d) | 2002-05-14 → 2002-06-17 (+34d) |  |  | 115d → 91d |  | resources Craig → On Hold |
| 33 | Build | 2002-05-15 → 2002-06-18 (+34d) | 2002-06-04 → 2002-07-08 (+34d) |  |  | 115d → 91d |  | resources ME TECH → On Hold |
| 34 | Test | 2002-06-05 → 2002-07-09 (+34d) | 2002-06-11 → 2002-07-15 (+34d) |  |  | 115d → 91d |  | resources Craig → On Hold |
| 36 | **Battery Electronics** | 2002-05-01 → 2002-06-04 A (+34d) | 2002-06-10 → 2002-08-23 (+74d) | 29d? → 59d? | 0% → 10% | 114d → 62d |  |  |
| 37 | Concept Design | 2002-05-01 → 2002-06-04 A (+34d) | 2002-05-07 → 2002-06-10 (+34d) |  | 0% → 50% | 122d → 100d |  |  |
| 38 | Design Review | 2002-05-08 → 2002-06-11 (+34d) | 2002-05-09 → 2002-06-12 (+34d) |  |  | 122d → 100d |  |  |
| 39 | Final Design | 2002-05-10 → 2002-06-13 (+34d) | 2002-05-24 → 2002-06-27 (+34d) |  |  | 122d → 100d |  |  |
| 40 | Build | 2002-05-27 → 2002-06-28 (+32d) | 2002-05-27 → 2002-06-28 (+32d) |  |  | 122d → 100d |  |  |
| 41 | Assemble | 2002-05-28 → 2002-07-01 (+34d) | 2002-05-28 → 2002-07-01 (+34d) |  |  | 122d → 100d |  |  |
| 42 | Test | 2002-05-29 → 2002-07-02 (+34d) | 2002-05-29 → 2002-07-02 (+34d) |  |  | 122d → 100d |  |  |
| 43 | Spec Misc Electronics (Contingency) | 2002-06-10 → 2002-08-20 (+71d) | 2002-06-10 → 2002-08-23 (+74d) | 1d? → 4d? |  | 114d → 62d |  |  |
| 44 | **Battery Charging** | 2002-06-11 → 2002-06-21 (+10d) | 2002-06-12 → 2002-06-26 (+14d) | 2d → 4d |  | 114d → 104d | 26, 36 → 26 |  |
| 45 | Spec Charging Analysis | 2002-06-11 → 2002-06-21 (+10d) | 2002-06-12 → 2002-06-24 (+12d) |  |  | 114d → 106d |  | constraint none → start no earlier than 2002-06-21 |
| 46 | Order Charging Equip as Required | 2002-06-11 → 2002-06-24 (+13d) | 2002-06-11 → 2002-06-26 (+15d) | 1d → 3d |  | 115d → 104d |  | constraint none → start no earlier than 2002-06-22 |
| 49 | **Cabling and Connectors** |  | 2002-06-21 → 2002-07-23 (+32d) | 42d → 64d | 41% → 44% | 107d → 85d |  | resources Drew → none |
| 50 | Spec Main Power / Comms Cable&Connectors/Penetrators |  | 2002-05-13 → 2002-06-12 A (+30d) |  | 50% → 100% | 124.66d → none |  |  |
| 51 | Spec Charging Connector | 2002-05-14 → 2002-06-12 A (+29d) | 2002-05-17 → 2002-06-18 (+32d) |  | 0% → 50% | 132d → 110.5d |  |  |
| 52 | Spec Tailcone Comms Cable&Connector/Penetrator |  | 2002-04-29 → 2002-06-05 A (+37d) | 3d → 4.4d | 80% → 100% | 134.66d → none |  |  |
| 58 | Order Connectors |  | 2002-05-15 → 2002-05-20 A (+5d) | 2d → 5d | 33% → 100% | 124d → none |  |  |
| 59 | **Tail to MVC** | 2002-05-09 → 2002-06-04 A (+26d) | 2002-05-09 → 2002-06-07 (+29d) | 1d → 4d | 0% → 30% | 128d → 107d |  |  |
| 60 | Section Interconnect | 2002-05-09 → 2002-06-04 A (+26d) | 2002-05-09 → 2002-06-07 (+29d) | 1d → 4d | 0% → 30% | 128d → 107d |  |  |
| 61 | Documetation package on Connectors and Cabling | 2002-06-10 → 2002-06-13 (+3d) | 2002-06-21 → 2002-06-26 (+5d) |  |  | 107d → 104d |  | constraint start no earlier than 2002-06-10 → start no earlier than 2002-06-13 |
| 64 | **Main Vehicle Computer** |  | 2002-09-19 → 2002-10-04 (+15d) | 135d → 146d | 33% → 44% | 43d → 32d |  |  |
| 65 | **Electronics** |  | 2002-06-05 → 2002-09-20 (+107d) | 59d → 136d | 45% → 60% | 119d → 42d |  |  |
| 67 | Order PC 104 Stack |  | 2002-05-07 A |  | 40% → 100% | 138.8d → none |  |  |
| 68 | Assemble PC 104 Stack | 2002-05-07 A | 2002-05-09 A |  | 0% → 100% | 138.8d → none |  |  |
| 69 | Develop latency test/budget for MVC | 2002-05-13 → 2002-05-27 A (+14d) | 2002-05-16 → 2002-06-07 (+22d) | 4d → 10d | 0% → 50% | 133d → 117d |  |  |
| 70 | **Power Board** |  | 2002-05-29 → 2002-06-19 (+21d) | 23d → 37.5d | 50% → 87% | 114d → 99.5d |  |  |
| 72 | Design |  | 2002-05-23 → 2002-06-13 A (+21d) |  | 50% → 100% | 114d → none |  |  |
| 73 | Order | 2002-05-24 → 2002-06-13 A (+20d) | 2002-05-24 → 2002-06-14 A (+21d) |  | 0% → 100% | 114d → none |  |  |
| 74 | Build | 2002-05-27 → 2002-06-14 (+18d) | 2002-05-28 → 2002-06-18 (+21d) |  |  | 114d → 99.5d |  |  |
| 75 | Test | 2002-05-29 → 2002-06-18 (+20d) | 2002-05-29 → 2002-06-19 (+21d) |  |  | 114d → 99.5d |  |  |
| 77 | Evaluate Data-link vs Freewave |  |  |  |  |  |  | resources Drew [50%] → Eric [50%] |
| 79 | **Acoustic Modem** | 2002-05-17 → 2002-09-16 A (+122d) | 2002-05-20 → 2002-09-20 (+123d) | 2d → 5d |  | 121d → 32d |  |  |
| 80 | Evaluate | 2002-05-17 → 2002-09-16 A (+122d) | 2002-05-17 → 2002-09-17 (+123d) | 1d → 2d |  | 121d → 32d |  |  |
| 81 | Purchase | 2002-05-20 → 2002-09-18 (+121d) | 2002-05-20 → 2002-09-20 (+123d) | 1d → 3d |  | 121d → 32d |  |  |
| 82 | **GPS** | 2002-05-16 → 2002-06-10 A (+25d) | 2002-06-05 → 2002-06-28 (+23d) |  |  | 109d → 92d |  | resources Drew → Eric |
| 83 | Evaluate GPS Position Fix Problem | 2002-05-16 → 2002-06-10 A (+25d) | 2002-05-29 → 2002-06-21 (+23d) |  |  | 109d → 92d |  | resources Craig → Eric |
| 84 | Evaluate GPS Board & Antennae | 2002-05-30 → 2002-06-24 (+25d) | 2002-06-04 → 2002-06-27 (+23d) |  |  | 109d → 92d |  | resources Craig → Eric |
| 85 | Purchase GPS Board & Antennae | 2002-06-05 → 2002-06-28 (+23d) | 2002-06-05 → 2002-06-28 (+23d) |  |  | 109d → 92d |  | resources Drew [25%] → Eric [25%] |
| 89 | Spec and Purcahse DVL |  | 2002-05-20 → 2002-08-09 (+81d) | 5d → 7d | 80% → 57% | 131d → 72d |  |  |
| 90 | **MVC Housing** |  | 2002-06-04 → 2002-07-09 (+35d) | 58d → 83d | 17% → 21% | 110d → 85d |  |  |
| 91 | Spec Interconnects |  | 2002-03-22 A |  | 80% → 100% | 140d → none |  |  |
| 92 | Design | 2002-05-06 → 2002-06-10 (+35d) | 2002-05-10 → 2002-06-14 (+35d) |  |  | 110d → 85d |  | constraint start no earlier than 2002-05-04 → start no earlier than 2002-06-09 |
| 93 | Build/Purchase | 2002-05-13 → 2002-06-17 (+35d) | 2002-05-24 → 2002-06-28 (+35d) |  |  | 110d → 85d |  |  |
| 94 | Pressure Test | 2002-05-27 → 2002-07-01 (+35d) | 2002-05-28 → 2002-07-02 (+35d) |  |  | 110d → 85d |  |  |
| 95 | Electronics Packagin Layout | 2002-05-29 → 2002-07-03 (+35d) | 2002-06-04 → 2002-07-09 (+35d) |  |  | 110d → 85d |  |  |
| 96 | **Documentation Package** | 2002-09-05 → 2002-09-23 (+18d) | 2002-09-19 → 2002-10-04 (+15d) | 11d → 10d |  | 43d → 32d |  |  |
| 97 | Mechanical | 2002-09-05 → 2002-09-23 (+18d) | 2002-09-06 → 2002-09-24 (+18d) |  |  | 50d → 38d |  |  |
| 98 | Electrical | 2002-09-05 → 2002-09-23 (+18d) | 2002-09-16 → 2002-10-02 (+16d) |  |  | 44d → 32d |  |  |
| 99 | Software | 2002-09-16 → 2002-09-23 (+7d) | 2002-09-17 → 2002-09-24 (+7d) |  |  | 43d → 38d |  |  |
| 100 | Integration | 2002-09-18 → 2002-10-03 (+15d) | 2002-09-19 → 2002-10-04 (+15d) |  |  | 43d → 32d |  |  |
| 113 | **Fairings / Vehicle Mechanical Structure** |  | 2002-07-05 → 2002-10-17 (+104d) | 81d → 155d | 5% → 14% | 97d → 23d |  | resources Drew → none |
| 114 | **L&R System Interface** |  | 2002-07-05 → 2002-08-02 (+28d) | 81d → 101d | 18% → 28% | 97d → 77d |  |  |
| 116 | Concept Design Review / Decision |  | 2002-05-24 A |  | 9% → 100% | 127d → none |  |  |
| 117 | Design L&R Interface | 2002-05-27 → 2002-06-24 (+28d) | 2002-06-07 → 2002-07-05 (+28d) |  |  | 97d → 77d |  | constraint start no earlier than 2002-05-27 → start no earlier than 2002-06-22 |
| 118 | Build Interface | 2002-06-10 → 2002-07-08 (+28d) | 2002-06-21 → 2002-07-19 (+28d) |  |  | 97d → 77d |  |  |

| ID | Task | Start | Finish | Duration | Complete | Total float | Other |
| --- | --- | --- | --- | --- | --- | --- | --- |
| 119 | Assemble Interface | 2002-06-24 → 2002-07-22 (+28d) | 2002-06-28 → 2002-07-26 (+28d) |  |  | 97d → 77d |  |
| 120 | L&R test plan | 2002-05-27 → 2002-06-24 (+28d) | 2002-05-30 → 2002-06-27 (+28d) |  |  | 118d → 98d | constraint start no earlier than 2002-05-26 → start no earlier than 2002-06-24 |
| 121 | Integrate and Test L&R Interface | 2002-07-01 → 2002-07-29 (+28d) | 2002-07-05 → 2002-08-02 (+28d) |  |  | 97d → 77d |  |
| 123 | **Joining Ring/Systems** | 2002-05-10 → 2002-09-02 (+115d) | 2002-07-01 → 2002-10-17 (+108d) | 37d → 34d |  | 101d → 23d |  |
| 124 | Evaluate joining ring systems | 2002-05-10 → 2002-09-02 (+115d) | 2002-05-13 → 2002-09-03 (+113d) |  |  | 104d → 23d | constraint start no earlier than 2002-05-10 → start no earlier than 2002-09-02 |
| 125 | Review Concept | 2002-05-14 → 2002-09-04 (+113d) | 2002-05-14 → 2002-09-04 (+113d) |  |  | 104d → 23d |  |
| 126 | Final Design | 2002-05-15 → 2002-09-05 (+113d) | 2002-06-04 → 2002-09-25 (+113d) |  |  | 104d → 23d |  |
| 127 | Build | 2002-06-05 → 2002-09-26 (+113d) | 2002-06-18 → 2002-10-09 (+113d) |  |  | 104d → 23d |  |
| 128 | Assemble | 2002-06-19 → 2002-10-10 (+113d) | 2002-06-21 → 2002-10-14 (+115d) |  |  | 104d → 23d |  |
| 129 | Test | 2002-06-24 → 2002-10-15 (+113d) | 2002-06-26 → 2002-10-17 (+113d) |  |  | 104d → 23d |  |
| 130 | Test new joining ring system | 2002-06-27 → 2002-09-17 (+82d) | 2002-07-01 → 2002-09-19 (+80d) |  |  | 101d → 43d | constraint start no earlier than 2002-06-27 → start no earlier than 2002-09-17 |
| 131 | **Deck Handling Equipment** | 2002-05-20 A | 2002-06-07 → 2002-09-18 (+103d) | 15d → 88d | 0% → 28% | 117d → 44d | resources Drew → none |
| 132 | New Cart Design | 2002-05-20 A | 2002-05-24 → 2002-07-05 (+42d) | 5d → 7d | 0% → 50% | 127d → 97d |  |
| 133 | New Lifitng Gear | 2002-05-27 A | 2002-05-31 → 2002-07-05 (+35d) | 5d → 7d | 0% → 30% | 122d → 97d |  |
| 134 | Sphere Lift Mechanism | 2002-05-21 → 2002-09-05 (+107d) | 2002-06-03 → 2002-09-18 (+107d) |  |  | 121d → 44d | constraint start no earlier than 2002-05-21 → start no earlier than 2002-09-05 |
| 135 | Eval Single Pt. Lift | 2002-05-23 A | 2002-05-24 A |  | 0% → 100% | 127d → none |  |
| 136 | Lifting I beam in Lab | 2002-05-30 A |  |  | 0% → 50% |  |  |
| 137 | Cable trays nad outlets in lab ceiling | 2002-06-03 → 2002-07-15 (+42d) | 2002-06-07 → 2002-07-19 (+42d) |  |  | 117d → 87d | constraint start no earlier than 2002-06-03 → start no earlier than 2002-07-14 |
| 138 | **Sensor & Payload Mounts** | 2002-05-20 → 2002-06-21 (+32d) | 2002-05-28 → 2002-06-27 (+30d) | 7d → 5d |  | 117d → 95d | resources Drew → none |
| 139 | Antennaes | 2002-05-20 → 2002-06-21 (+32d) | 2002-05-24 → 2002-06-27 (+34d) |  |  | 119d → 95d | constraint start no earlier than 2002-05-18 → start no earlier than 2002-06-21 |
| 140 | ORE & various equip | 2002-05-23 → 2002-06-24 (+32d) | 2002-05-28 → 2002-06-27 (+30d) |  |  | 117d → 95d | constraint start no earlier than 2002-05-23 → start no earlier than 2002-06-24 |
| 141 | **Buoyancy** | 2002-05-22 → 2002-06-13 (+22d) | 2002-06-04 → 2002-07-11 (+37d) | 10d → 21d |  | 112d → 85d | resources Drew → none |
| 142 | Tailcone Foam Pack Specification | 2002-05-22 → 2002-06-28 (+37d) | 2002-05-28 → 2002-07-04 (+37d) |  |  | 112d → 85d | constraint start no earlier than 2002-05-22 → start no earlier than 2002-06-28 |
| 143 | Tailcone foam machining | 2002-05-29 → 2002-07-05 (+37d) | 2002-06-04 → 2002-07-11 (+37d) |  |  | 112d → 85d |  |
| 144 | Modular trim / ballast systems concept | 2002-05-22 → 2002-06-13 (+22d) | 2002-05-28 → 2002-06-24 (+27d) | 5d → 8d |  | 117d → 98d | constraint start no earlier than 2002-05-22 → start no earlier than 2002-06-13 |
| 145 | **Fairing Build** | 2002-06-10 → 2002-07-12 (+32d) | 2002-06-26 → 2002-07-23 (+27d) | 13d → 8d |  | 104d → 85d | resources Drew → none |
| 146 | Noes section (2 plus 1 spare) | 2002-06-10 → 2002-07-12 (+32d) | 2002-06-19 → 2002-07-23 (+34d) |  |  | 109d → 85d |  |
| 147 | Midboady (2 plus 1 spare) | 2002-06-13 → 2002-07-12 (+29d) | 2002-06-24 → 2002-07-23 (+29d) |  |  | 106d → 85d |  |
| 148 | Tail section (2 plus 1 spare) | 2002-06-17 → 2002-07-12 (+25d) | 2002-06-26 → 2002-07-23 (+27d) |  |  | 104d → 85d |  |
| 150 | **Software** | 2002-06-24 → 2002-06-06 A (-18d) |  | 107d → 119d | 0% → 4% |  |  |
| 156 | **GUI** | 2002-07-02 → 2002-06-06 (-26d) | 2002-09-09 → 2002-08-14 (-26d) |  |  | 51d → 69d |  |
| 157 | gather requirements | 2002-07-02 → 2002-06-06 (-26d) | 2002-07-08 → 2002-06-12 (-26d) |  |  | 51d → 69d | constraint start no earlier than 2002-07-02 → start no earlier than 2002-06-06 |
| 158 | eval Bluefin GUI | 2002-07-09 → 2002-06-13 (-26d) | 2002-07-22 → 2002-06-26 (-26d) |  |  | 51d → 69d |  |
| 159 | develop GUI plan | 2002-07-23 → 2002-06-27 (-26d) | 2002-07-29 → 2002-07-03 (-26d) |  |  | 51d → 69d |  |
| 160 | Detail GUI development (TBD) | 2002-07-30 → 2002-07-04 (-26d) | 2002-09-09 → 2002-08-14 (-26d) |  |  | 51d → 69d |  |
| 161 | Configuration management on vehicle (config files) | 2002-08-16 → 2002-07-09 (-38d) | 2002-09-05 → 2002-07-29 (-38d) |  |  | 53d → 81d | constraint start no earlier than 2002-08-16 → start no earlier than 2002-07-09 |
| 162 | **Controls** | 2002-06-24 → 2002-07-19 (+25d) | 2002-08-23 → 2002-09-19 (+27d) |  |  | 62d → 43d |  |
| 163 | depth control improvement (long configs) | 2002-06-24 → 2002-07-19 (+25d) | 2002-07-12 → 2002-08-08 (+27d) |  |  | 62d → 43d | constraint start no earlier than 2002-06-22 → start no earlier than 2002-07-19 |
| 164 | sway / yaw control coupling (heave/ pitch too) | 2002-07-15 → 2002-08-09 (+25d) | 2002-07-26 → 2002-08-22 (+27d) |  |  | 62d → 43d |  |
| 165 | slow speed dynamics for control | 2002-07-29 → 2002-08-23 (+25d) | 2002-08-23 → 2002-09-19 (+27d) |  |  | 62d → 43d |  |
| 166 | **Navigation Software** | 2002-09-23 A |  |  | 0% → 13% |  |  |
| 171 | DVL driver enhancements for PD5 | 2002-10-09 A |  |  | 0% → 50% |  |  |
| 176 | **Vehicle Integration and Test** | 2002-06-10 → 2002-07-18 (+38d) | 2002-08-02 → 2002-09-04 (+33d) | 40d → 35d |  | 76d → 53d |  |
| 177 | Tailcone Assembly | 2002-06-10 → 2002-07-18 (+38d) | 2002-06-14 → 2002-07-24 (+40d) |  |  | 86d → 62d | constraint start no earlier than 2002-06-08 → start no earlier than 2002-07-18 |
| 178 | Tailcone Test | 2002-06-17 → 2002-07-25 (+38d) | 2002-06-20 → 2002-07-30 (+40d) |  |  | 86d → 62d |  |
| 179 | Battery Midbody Integration | 2002-06-17 → 2002-07-31 (+44d) | 2002-06-21 → 2002-08-06 (+46d) |  |  | 81d → 53d | constraint start no earlier than 2002-06-17 → start no earlier than 2002-07-31 |
| 180 | Battery Midbody Test | 2002-06-24 → 2002-08-07 (+44d) | 2002-06-27 → 2002-08-12 (+46d) |  |  | 81d → 53d |  |
| 181 | ALTEX Nose Payload Assembly/Upgrade | 2002-06-17 → 2002-07-19 (+32d) | 2002-06-21 → 2002-07-25 (+34d) |  |  | 76d → 56d | constraint start no earlier than 2002-06-17 → start no earlier than 2002-07-19 |
| 182 | Science Payload Assembly | 2002-06-24 → 2002-07-26 (+32d) | 2002-07-01 → 2002-08-02 (+32d) |  |  | 76d → 56d |  |
| 183 | Payload Test | 2002-07-02 → 2002-08-05 (+34d) | 2002-07-04 → 2002-08-07 (+34d) |  |  | 76d → 56d |  |
| 184 | Integrated Vehcile Deck Assembly | 2002-07-05 → 2002-08-13 (+39d) | 2002-07-08 → 2002-08-14 (+37d) |  |  | 76d → 53d |  |
| 185 | Vehicle Ballasting | 2002-07-09 → 2002-08-15 (+37d) | 2002-07-09 → 2002-08-15 (+37d) |  |  | 76d → 53d |  |
| 186 | Integrated Vehicle Deck Test | 2002-07-10 → 2002-08-16 (+37d) | 2002-07-12 → 2002-08-20 (+39d) |  |  | 76d → 53d |  |
| 187 | Integrated Vehicle Tank Test | 2002-07-15 → 2002-08-21 (+37d) | 2002-07-19 → 2002-08-27 (+39d) |  |  | 76d → 53d |  |
| 188 | Integrated Vehicle Sea Trials | 2002-07-22 → 2002-08-28 (+37d) | 2002-08-02 → 2002-09-04 (+33d) | 10d → 6d |  | 76d → 53d |  |
| 190 | **CTD Science Payload Core** | 2002-06-20 → 2002-06-27 A (+7d) | 2002-08-05 → 2002-09-05 (+31d) | 33d? → 51d? | 0% → 8% | 76d → 53d |  |
| 191 | Repair/Replace nose fairing | 2002-06-20 → 2002-07-22 (+32d) | 2002-06-24 → 2002-07-24 (+30d) |  |  | 100d → 78d | constraint start no earlier than 2002-06-20 → start no earlier than 2002-07-20 |
| 192 | recable Dcon to comms and pwr bus | 2002-06-21 → 2002-07-29 (+38d) | 2002-07-02 → 2002-08-07 (+36d) |  |  | 96d → 70d | constraint start no earlier than 2002-06-21 → start no earlier than 2002-07-27 |
| 193 | Design HS2 Mount | 2002-06-25 → 2002-07-25 (+30d) | 2002-06-26 → 2002-07-26 (+30d) |  |  | 100d → 78d |  |
| 194 | Build HS2 Mount | 2002-06-27 → 2002-07-29 (+32d) | 2002-06-28 → 2002-07-30 (+32d) |  |  | 100d → 78d |  |
| 195 | Assembly HS2 Mount | 2002-07-01 → 2002-07-31 (+30d) | 2002-07-02 → 2002-08-01 (+30d) |  |  | 100d → 78d |  |
| 196 | Write test driver HS2 | 2002-06-27 A |  |  | 0% → 50% |  |  |
| 198 | repair flow sensor #2 | 2002-07-03 → 2002-08-08 (+36d) | 2002-07-05 → 2002-08-12 (+38d) |  |  | 96d → 70d |  |
| 199 | test integrated CTD Payload | 2002-08-05 → 2002-09-05 (+31d) | 2002-08-05 → 2002-09-05 (+31d) |  |  | 76d → 53d |  |
| 201 | **CTD Extension for Ryan/Haddock** | 2002-06-03 → 2002-06-27 (+24d) | 2002-07-01 → 2002-07-25 (+24d) |  |  | 101d → 83d |  |
| 202 | Design LISST pump assy | 2002-06-03 → 2002-06-27 (+24d) | 2002-06-06 → 2002-07-02 (+26d) |  |  | 101d → 83d | constraint start no earlier than 2002-06-03 → start no earlier than 2002-06-27 |
| 203 | Fab LISST pump assy | 2002-06-07 → 2002-07-03 (+26d) | 2002-06-13 → 2002-07-09 (+26d) |  |  | 104d → 86d |  |
| 204 | Assy LISST pump into vehicle | 2002-06-14 → 2002-07-10 (+26d) | 2002-06-17 → 2002-07-11 (+24d) |  |  | 104d → 86d |  |
| 205 | Design LISST mount | 2002-06-07 → 2002-07-03 (+26d) | 2002-06-13 → 2002-07-09 (+26d) |  |  | 101d → 83d |  |
| 206 | Fab LISST Mount | 2002-06-14 → 2002-07-10 (+26d) | 2002-06-20 → 2002-07-16 (+26d) |  |  | 101d → 83d |  |

| ID | Task | Start | Finish | Total float | Other |
| --- | --- | --- | --- | --- | --- |
| 207 | Assy LISST mount | 2002-06-21 → 2002-07-17 (+26d) | 2002-06-24 → 2002-07-18 (+24d) | 101d → 83d |  |
| 208 | Cable LISST to Dcon | 2002-06-25 → 2002-07-19 (+24d) | 2002-06-25 → 2002-07-19 (+24d) | 105d → 87d |  |
| 209 | Write Test Driver for LISST | 2002-06-25 → 2002-07-19 (+24d) | 2002-07-01 → 2002-07-25 (+24d) | 101d → 83d |  |
| 210 | Design Bathypho mount | 2002-06-05 → 2002-07-03 (+28d) | 2002-06-10 → 2002-07-08 (+28d) | 105d → 85d | constraint start no earlier than 2002-06-05 → start no earlier than 2002-07-03 |
| 211 | Fab Bathypho mount | 2002-06-11 → 2002-07-09 (+28d) | 2002-06-17 → 2002-07-15 (+28d) | 105d → 85d |  |
| 212 | Assy Bathypho mount | 2002-06-18 → 2002-07-16 (+28d) | 2002-06-19 → 2002-07-17 (+28d) | 105d → 85d |  |
| 213 | Cable Bathypho to Dcon | 2002-06-20 → 2002-07-18 (+28d) | 2002-06-20 → 2002-07-18 (+28d) | 105d → 85d |  |
| 214 | Retest driver for Bathypho (already written) | 2002-06-21 → 2002-07-19 (+28d) | 2002-06-25 → 2002-07-23 (+28d) | 105d → 85d |  |
| 216 | Ryan / Haddock Cruise Prep | 2002-07-29 → 2002-08-05 (+7d) | 2002-08-15 → 2002-08-22 (+7d) | 68d → 63d | constraint start no earlier than 2002-07-27 → start no earlier than 2002-08-05 |

## Version 4 (data date 2002-06-03, saved 2002-07-19, file Dorado2002revG.mpp)

Last finish stays 2002-11-19. Complete tasks 27 → 33.

Added:

| ID | Task | Duration | Start | Finish | Predecessors | Constraint | Resources |
| --- | --- | --- | --- | --- | --- | --- | --- |
| 40 | Potted Junction | 21d? | 2002-07-01 | 2002-07-29 |  | start no earlier than 2002-06-30 | Sib; Hans |
| 218 | JBOX and tether fix | 6d? | 2002-06-26 | 2002-07-03 |  | start no earlier than 2002-06-26 |  |
| 219 | External Parosci mounted | 6d? | 2002-06-26 | 2002-07-03 |  | start no earlier than 2002-06-26 |  |
| 220 | Dcon housing modifications | 13d? | 2002-06-26 | 2002-07-12 |  | start no earlier than 2002-06-26 |  |
| 221 | CTD nose section complete | 23d? | 2002-06-26 | 2002-07-26 |  | start no earlier than 2002-06-26 |  |
| 222 | Bathy and Lisst mounted | 23d? | 2002-06-26 | 2002-07-26 |  | start no earlier than 2002-06-26 |  |
| 223 | GPS Soltuion in place | 23d? | 2002-06-26 | 2002-07-26 |  | start no earlier than 2002-06-26 |  |
| 224 | New battery sphere | 25d? | 2002-07-01 | 2002-08-02 |  | start no earlier than 2002-07-01 |  |
| 225 | Three AgZn bats charged | 10d? | 2002-07-22 | 2002-08-02 |  | start no earlier than 2002-07-22 |  |
| 226 | Hardware freeze date | 1d? | 2002-08-02 | 2002-08-02 |  | start no earlier than 2002-08-02 |  |
| 227 | Vehicle buttoned up and ready | 2d? | 2002-08-01 | 2002-08-02 |  | start no earlier than 2002-08-01 |  |
| 228 | Mobilize Zephyr | 2d? | 2002-08-01 | 2002-08-02 |  | start no earlier than 2002-08-01 |  |
| 229 | Sea trials of vehicle | 5d? | 2002-08-05 | 2002-08-09 | 228, 227, 225 | start no earlier than 2002-08-05 |  |
| 230 | Tracking pole and sng pt lift | 25d? | 2002-07-15 | 2002-08-16 |  | start no earlier than 2002-07-15 |  |
| 231 | Mob of PT Sur | 2d? | 2002-08-16 | 2002-08-19 |  | start no earlier than 2002-08-16 |  |
| 232 | Off-board data analysis | 7d? | 2002-08-09 | 2002-08-19 |  | start no earlier than 2002-08-09 |  |
| 233 | Ocean complexity cruise | 6d? | 2002-08-20 | 2002-08-27 | 231, 230 | start no earlier than 2002-08-20 |  |
| 234 | Demob Pt Sur | 2d? | 2002-08-28 | 2002-08-29 | 233 | start no earlier than 2002-08-27 |  |

Changed:

| ID | Task | Start | Finish | Duration | Complete | Total float | Predecessors | Other |
| --- | --- | --- | --- | --- | --- | --- | --- | --- |
| 1 | **Dorado Program** |  |  |  | 15% → 16% |  |  |  |
| 3 | **Propulsion** |  |  |  | 10% → 14% |  |  | baseline start 2002-05-02 → 2002-05-20; baseline finish 2002-09-17 → 2002-09-18 |
| 4 | **Articulated Tail** |  |  |  |  |  |  | baseline start 2002-05-02 → 2002-05-20 |
| 5 | Design & Build New Electronics Housing |  | 2002-06-19 → 2002-07-18 (+29d) |  |  | 104d → 83.5d |  | resources Farley → Robert F; baseline start 2002-05-02 → 2002-05-20; baseline finish 2002-05-15 → 2002-07-18 |
| 7 | **Drive Electronics** | 2002-05-27 A → 2002-07-11 A (+45d) | 2002-07-22 → 2002-08-13 (+22d) | 41d → 24d |  | 81d → 65d |  | baseline start 2002-05-06 → 2002-07-11; baseline finish 2002-06-06 → 2002-08-13 |
| 8 | Integrate New Electroincs | 2002-06-19 A → 2002-07-11 A (+22d) | 2002-07-22 → 2002-08-13 (+22d) |  |  | 81d → 65d |  | baseline start 2002-05-06 → 2002-07-11; baseline finish 2002-06-06 → 2002-08-13 |
| 9 | Cabling | 2002-05-27 → 2002-08-01 (+66d) | 2002-05-31 → 2002-08-07 (+68d) |  |  | 117d → 69d |  | constraint start no earlier than 2002-05-27 → start no earlier than 2002-08-01; baseline start 2002-05-27 → 2002-08-01; baseline finish 2002-05-31 → 2002-08-07 |
| 10 | Integrate New Tail Into fairing | 2002-07-23 → 2002-08-14 (+22d) | 2002-07-29 → 2002-08-20 (+22d) |  |  | 81d → 65d |  | baseline start 2002-06-07 → 2002-08-14; baseline finish 2002-06-13 → 2002-08-20 |
| 11 | Tailcone - Bench Stand Design and Fab | 2002-05-27 → 2002-08-01 (+66d) | 2002-05-29 → 2002-08-05 (+68d) |  |  | 124d → 76d |  | constraint start no earlier than 2002-05-27 → start no earlier than 2002-08-01; baseline start 2002-05-27 → 2002-08-01; baseline finish 2002-05-29 → 2002-08-05 |
| 13 | Test Plan | 2002-06-14 → 2002-07-04 (+20d) | 2002-06-20 → 2002-07-10 (+20d) |  |  | 108d → 94d |  | constraint start no earlier than 2002-06-14 → start no earlier than 2002-07-04; baseline start 2002-06-14 → 2002-07-04; baseline finish 2002-06-20 → 2002-07-10 |
| 14 | Replace foam with 4500 M | 2002-06-17 A |  |  | 0% → 25% |  |  | constraint start no earlier than 2002-06-17 → start no earlier than 2002-06-16; baseline start none → 2002-06-17; baseline finish none → 2002-07-12 |
| 15 | Compensator Design/Purchase | 2002-06-10 → 2002-06-11 (+1d) | 2002-07-05 → 2002-07-08 (+3d) |  |  | 97d → 96d |  | constraint start no earlier than 2002-06-10 → start no earlier than 2002-06-11; baseline start none → 2002-06-11; baseline finish none → 2002-07-08 |
| 16 | **Tailcone Documetation** |  |  |  |  |  |  | baseline finish 2002-09-17 → 2002-09-18 |
| 17 | Mechanical |  |  |  |  |  |  | baseline finish 2002-09-16 → 2002-09-18 |
| 21 | **Power** |  | 2002-08-23 → 2002-09-11 (+19d) | 95d? → 108d? | 10% → 12% | 62d → 49d |  | baseline finish 2002-06-24 → 2002-09-11 |
| 22 | **Battery Chemistry** |  | 2002-08-19 → 2002-09-05 (+17d) | 91d? → 104d? |  | 66d → 53d |  | baseline finish 2002-05-23 → 2002-09-05 |
| 26 | Design Review of Batt Chems |  |  |  |  |  |  | baseline start 2002-04-24 → 2002-06-03; baseline finish 2002-04-24 → 2002-06-03 |
| 27 | Purchase Batteries | 2002-06-04 → 2002-06-27 (+23d) | 2002-06-07 → 2002-07-02 (+25d) |  |  | 66d → 49d |  | constraint none → start no earlier than 2002-06-27; baseline start 2002-04-25 → 2002-06-27; baseline finish 2002-04-25 → 2002-07-02 |
| 28 | Battery delivery | 2002-06-14 → 2002-07-03 (+19d) | 2002-08-08 → 2002-08-27 (+19d) |  |  | 62d → 49d |  | baseline start none → 2002-07-03; baseline finish none → 2002-08-27 |
| 29 | Assemble Batteries | 2002-08-09 → 2002-08-28 (+19d) | 2002-08-14 → 2002-09-02 (+19d) |  |  | 62d → 49d |  | baseline start 2002-04-26 → 2002-08-28; baseline finish 2002-05-02 → 2002-09-02 |
| 30 | Test Batteries | 2002-08-15 → 2002-09-03 (+19d) | 2002-08-19 → 2002-09-05 (+17d) |  |  | 62d → 49d |  | baseline start 2002-05-03 → 2002-09-03; baseline finish 2002-05-23 → 2002-09-05 |
| 31 | **Battery Housing** |  |  |  |  |  |  | baseline finish 2002-06-11 → 2002-07-15 |
| 32 | Design |  |  |  |  |  |  | baseline start 2002-05-01 → 2002-06-04; baseline finish 2002-05-14 → 2002-06-17 |
| 33 | Build |  |  |  |  |  |  | baseline start 2002-05-15 → 2002-06-18; baseline finish 2002-06-04 → 2002-07-08 |
| 34 | Test |  |  |  |  |  |  | baseline start 2002-06-05 → 2002-07-09; baseline finish 2002-06-11 → 2002-07-15 |
| 36 | **Battery Electronics** |  | 2002-08-23 → 2002-09-11 (+19d) | 59d? → 72d? | 10% → 6% | 62d → 49d |  | baseline start 2002-05-01 → 2002-06-04; baseline finish 2002-06-10 → 2002-09-11 |
| 37 | Concept Design |  | 2002-06-10 → 2002-06-07 (-3d) | 5d → 4d | 50% → 63% | 100d → 104d |  | resources Sib → On Hold; baseline start 2002-05-01 → 2002-06-04; baseline finish 2002-05-07 → 2002-06-07 |
| 38 | Design Review | 2002-06-11 → 2002-06-10 (-1d) | 2002-06-12 → 2002-06-11 (-1d) |  |  | 100d → 104d |  | resources Sib → On Hold; baseline start 2002-05-08 → 2002-06-10; baseline finish 2002-05-09 → 2002-06-11 |
| 39 | Final Design | 2002-06-13 → 2002-06-12 (-1d) | 2002-06-27 → 2002-06-26 (-1d) |  |  | 100d → 104d |  | resources Sib [75%] → On Hold [75%]; baseline start 2002-05-10 → 2002-06-12; baseline finish 2002-05-24 → 2002-06-26 |
| 41 | Build | 2002-06-28 → 2002-09-02 (+66d) | 2002-06-28 → 2002-09-02 (+66d) |  |  | 100d → 54d | 39 → 40 | constraint none → start no earlier than 2002-09-02; baseline start 2002-05-27 → 2002-09-02; baseline finish 2002-05-27 → 2002-09-02 |
| 42 | Assemble | 2002-07-01 → 2002-09-03 (+64d) | 2002-07-01 → 2002-09-03 (+64d) |  |  | 100d → 54d |  | baseline start 2002-05-28 → 2002-09-03; baseline finish 2002-05-28 → 2002-09-03 |
| 43 | Test | 2002-07-02 → 2002-09-04 (+64d) | 2002-07-02 → 2002-09-04 (+64d) |  |  | 100d → 54d |  | baseline start 2002-05-29 → 2002-09-04; baseline finish 2002-05-29 → 2002-09-04 |
| 44 | Spec Misc Electronics (Contingency) | 2002-08-20 → 2002-09-06 (+17d) | 2002-08-23 → 2002-09-11 (+19d) |  |  | 62d → 49d |  | baseline start 2002-06-10 → 2002-09-06; baseline finish 2002-06-10 → 2002-09-11 |
| 45 | **Battery Charging** | 2002-06-21 A | 2002-06-26 → 2002-07-25 (+29d) | 4d → 25d | 0% → 33% | 104d → 83d |  | baseline start 2002-06-11 → 2002-06-21; baseline finish 2002-06-12 → 2002-07-25 |
| 46 | Spec Charging Analysis | 2002-06-21 A | 2002-06-24 A |  | 0% → 100% | 106d → none |  | baseline start 2002-06-11 → 2002-06-21; baseline finish 2002-06-12 → 2002-06-24 |
| 47 | Order Charging Equip as Required | 2002-06-24 → 2002-07-22 (+28d) | 2002-06-26 → 2002-07-25 (+29d) | 3d → 4d |  | 104d → 83d |  | constraint start no earlier than 2002-06-22 → start no earlier than 2002-07-21; baseline start 2002-06-11 → 2002-07-22; baseline finish 2002-06-11 → 2002-07-25 |
| 48 | AUV Power Systems Meeting | 2002-06-19 A | 2002-06-24 A |  | 0% → 100% | 106d → none |  | resources Hans → Ed |
| 50 | **Cabling and Connectors** |  |  |  | 44% → 72% |  |  | baseline finish 2002-06-21 → 2002-07-23 |
| 51 | Spec Main Power / Comms Cable&Connectors/Penetrators |  |  |  |  |  |  | baseline finish 2002-05-13 → 2002-06-12 |
| 52 | Spec Charging Connector |  | 2002-06-18 → 2002-07-18 (+30d) | 4d → 6d | 50% → 33% | 110.5d → 88d |  | baseline start 2002-05-14 → 2002-06-12; baseline finish 2002-05-17 → 2002-07-18 |
| 53 | Spec Tailcone Comms Cable&Connector/Penetrator |  |  |  |  |  |  | baseline finish 2002-04-29 → 2002-06-05 |
| 59 | Order Connectors |  |  |  |  |  |  | baseline finish 2002-05-15 → 2002-05-20 |
| 60 | **Tail to MVC** |  | 2002-06-07 A |  | 30% → 100% | 107d → none |  | baseline start 2002-05-09 → 2002-06-04; baseline finish 2002-05-09 → 2002-06-07 |
| 61 | Section Interconnect |  | 2002-06-07 A |  | 30% → 100% | 107d → none |  | baseline start 2002-05-09 → 2002-06-04; baseline finish 2002-05-09 → 2002-06-07 |
| 62 | Documetation package on Connectors and Cabling | 2002-06-13 A | 2002-06-26 A |  | 0% → 100% | 104d → none |  | baseline start 2002-06-10 → 2002-06-13; baseline finish 2002-06-21 → 2002-06-26 |
| 63 | Cable Assy @ Seacon | 2002-06-18 A |  |  | 0% → 35% |  |  | baseline start none → 2002-06-18; baseline finish none → 2002-07-23 |
| 65 | **Main Vehicle Computer** |  |  |  | 44% → 52% |  |  | baseline finish 2002-09-19 → 2002-10-04 |
| 66 | **Electronics** |  |  |  | 60% → 68% |  |  | baseline finish 2002-06-05 → 2002-09-20 |
| 70 | Develop latency test/budget for MVC |  | 2002-06-07 → 2002-07-19 (+42d) |  |  | 117d → 87d |  | baseline start 2002-05-13 → 2002-05-27; baseline finish 2002-05-16 → 2002-07-19 |
| 71 | **Power Board** |  | 2002-06-19 → 2002-07-11 (+22d) | 37.5d → 54d | 87% → 96% | 99.5d → 83d |  | baseline finish 2002-05-29 → 2002-07-11 |
| 73 | Design |  |  |  |  |  |  | baseline finish 2002-05-23 → 2002-06-13 |
| 74 | Order |  |  |  |  |  |  | baseline start 2002-05-24 → 2002-06-13; baseline finish 2002-05-24 → 2002-06-14 |
| 75 | Build | 2002-06-14 A | 2002-06-18 A |  | 0% → 100% | 99.5d → none |  | baseline start 2002-05-27 → 2002-06-14; baseline finish 2002-05-28 → 2002-06-18 |
| 76 | Test | 2002-06-18 → 2002-07-11 (+23d) | 2002-06-19 → 2002-07-11 (+22d) |  |  | 99.5d → 83d |  | constraint none → start no earlier than 2002-07-11; baseline start 2002-05-29 → 2002-07-11; baseline finish 2002-05-29 → 2002-07-11 |
| 77 | **RF Modem** |  | 2002-05-15 → 2002-06-27 A (+43d) | 44d → 75d | 71% → 100% | 134d → none |  | baseline finish 2002-05-15 → 2002-06-27 |
| 79 | Purchase | 2002-05-14 → 2002-06-26 A (+43d) | 2002-05-15 → 2002-06-27 A (+43d) |  | 0% → 100% | 134d → none |  | constraint start no earlier than 2002-05-14 → start no earlier than 2002-06-26; baseline start 2002-05-14 → 2002-06-26; baseline finish 2002-05-15 → 2002-06-27 |
| 80 | **Acoustic Modem** |  |  |  |  |  |  | baseline start 2002-05-17 → 2002-09-16; baseline finish 2002-05-20 → 2002-09-20 |
| 81 | Evaluate |  |  |  |  |  |  | baseline start 2002-05-17 → 2002-09-16; baseline finish 2002-05-17 → 2002-09-17 |
| 82 | Purchase |  |  |  |  |  |  | baseline start 2002-05-20 → 2002-09-18; baseline finish 2002-05-20 → 2002-09-20 |
| 83 | **GPS** | 2002-06-10 A → 2002-07-06 A (+26d) | 2002-06-28 → 2002-07-26 (+28d) |  | 0% → 20% | 92d → 72d |  | baseline start 2002-05-16 → 2002-06-10; baseline finish 2002-06-05 → 2002-06-28 |
| 84 | Evaluate GPS Position Fix Problem | 2002-06-10 A → 2002-07-06 A (+26d) | 2002-06-21 → 2002-07-19 (+28d) |  | 0% → 30% | 92d → 72d |  | baseline start 2002-05-16 → 2002-06-10; baseline finish 2002-05-29 → 2002-06-21 |
| 85 | Evaluate GPS Board & Antennae | 2002-06-24 → 2002-07-22 (+28d) | 2002-06-27 → 2002-07-25 (+28d) |  |  | 92d → 72d |  | baseline start 2002-05-30 → 2002-06-24; baseline finish 2002-06-04 → 2002-06-27 |
| 86 | Purchase GPS Board & Antennae | 2002-06-28 → 2002-07-26 (+28d) | 2002-06-28 → 2002-07-26 (+28d) |  |  | 92d → 72d |  | baseline start 2002-06-05 → 2002-06-28; baseline finish 2002-06-05 → 2002-06-28 |
| 90 | Spec and Purcahse DVL |  |  |  |  |  |  | baseline finish 2002-05-20 → 2002-08-09 |
| 91 | **MVC Housing** |  | 2002-07-09 → 2002-08-06 (+28d) | 83d → 103d | 21% → 30% | 85d → 65d |  | baseline finish 2002-06-04 → 2002-07-09 |
| 93 | Design | 2002-06-10 → 2002-07-08 A (+28d) | 2002-06-14 → 2002-07-12 (+28d) |  | 0% → 50% | 85d → 65d |  | constraint start no earlier than 2002-06-09 → start no earlier than 2002-07-08; resources Farley → Robert F; baseline start 2002-05-06 → 2002-06-10; baseline finish 2002-05-10 → 2002-06-14 |
| 94 | Build/Purchase | 2002-06-17 → 2002-07-15 (+28d) | 2002-06-28 → 2002-07-26 (+28d) |  |  | 85d → 65d |  | baseline start 2002-05-13 → 2002-06-17; baseline finish 2002-05-24 → 2002-06-28 |
| 95 | Pressure Test | 2002-07-01 → 2002-07-29 (+28d) | 2002-07-02 → 2002-07-30 (+28d) |  |  | 85d → 65d |  | baseline start 2002-05-27 → 2002-07-01; baseline finish 2002-05-28 → 2002-07-02 |
| 96 | Electronics Packagin Layout | 2002-07-03 → 2002-07-31 (+28d) | 2002-07-09 → 2002-08-06 (+28d) |  |  | 85d → 65d |  | baseline start 2002-05-29 → 2002-07-03; baseline finish 2002-06-04 → 2002-07-09 |
| 97 | **Documentation Package** |  |  |  |  |  |  | baseline start 2002-09-05 → 2002-09-23; baseline finish 2002-09-19 → 2002-10-04 |

| ID | Task | Start | Finish | Duration | Complete | Total float | Predecessors | Other |
| --- | --- | --- | --- | --- | --- | --- | --- | --- |
| 98 | Mechanical |  |  |  |  |  |  | baseline start 2002-09-05 → 2002-09-23; baseline finish 2002-09-06 → 2002-09-24 |
| 99 | Electrical |  |  |  |  |  |  | baseline start 2002-09-05 → 2002-09-23; baseline finish 2002-09-16 → 2002-10-02 |
| 100 | Software |  |  |  |  |  |  | baseline start 2002-09-16 → 2002-09-23; baseline finish 2002-09-17 → 2002-09-24 |
| 101 | Integration |  |  |  |  |  |  | baseline start 2002-09-18 → 2002-10-03; baseline finish 2002-09-19 → 2002-10-04 |
| 114 | **Fairings / Vehicle Mechanical Structure** |  |  |  | 14% → 15% |  |  | baseline finish 2002-07-05 → 2002-10-17 |
| 115 | **L&R System Interface** |  | 2002-08-02 → 2002-09-27 (+56d) | 101d → 141d |  | 77d → 37d |  | resources Drew → none; baseline finish 2002-07-05 → 2002-08-02 |
| 118 | Design L&R Interface |  |  |  |  |  |  | resources Farley → Drew; baseline start 2002-05-27 → 2002-06-24; baseline finish 2002-06-07 → 2002-07-05 |
| 119 | Build Interface |  |  |  |  |  |  | resources Shop → Brooke OS; baseline start 2002-06-10 → 2002-07-08; baseline finish 2002-06-21 → 2002-07-19 |
| 120 | Assemble Interface |  |  |  |  |  |  | resources ME TECH → Brooke OS; baseline start 2002-06-24 → 2002-07-22; baseline finish 2002-06-28 → 2002-07-26 |
| 121 | L&R test plan | 2002-06-24 → 2002-08-05 (+42d) | 2002-06-27 → 2002-08-08 (+42d) |  |  | 98d → 68d |  | constraint start no earlier than 2002-06-24 → start no earlier than 2002-08-03; baseline start 2002-05-27 → 2002-06-24; baseline finish 2002-05-30 → 2002-06-27 |
| 122 | Integrate and Test L&R Interface | 2002-07-29 → 2002-09-23 (+56d) | 2002-08-02 → 2002-09-27 (+56d) |  |  | 77d → 37d |  | constraint none → start no earlier than 2002-09-22; baseline start 2002-07-01 → 2002-07-29; baseline finish 2002-07-05 → 2002-08-02 |
| 124 | **Joining Ring/Systems** |  |  |  |  |  |  | baseline start 2002-05-10 → 2002-09-02; baseline finish 2002-07-01 → 2002-10-17 |
| 125 | Evaluate joining ring systems |  |  |  |  |  |  | baseline start 2002-05-10 → 2002-09-02; baseline finish 2002-05-13 → 2002-09-03 |
| 126 | Review Concept |  |  |  |  |  |  | baseline start 2002-05-14 → 2002-09-04; baseline finish 2002-05-14 → 2002-09-04 |
| 127 | Final Design |  |  |  |  |  |  | baseline start 2002-05-15 → 2002-09-05; baseline finish 2002-06-04 → 2002-09-25 |
| 128 | Build |  |  |  |  |  |  | baseline start 2002-06-05 → 2002-09-26; baseline finish 2002-06-18 → 2002-10-09 |
| 129 | Assemble |  |  |  |  |  |  | baseline start 2002-06-19 → 2002-10-10; baseline finish 2002-06-21 → 2002-10-14 |
| 130 | Test |  |  |  |  |  |  | baseline start 2002-06-24 → 2002-10-15; baseline finish 2002-06-26 → 2002-10-17 |
| 131 | Test new joining ring system |  |  |  |  |  |  | baseline start 2002-06-27 → 2002-09-17; baseline finish 2002-07-01 → 2002-09-19 |
| 132 | **Deck Handling Equipment** |  |  |  | 28% → 27% |  |  | baseline finish 2002-06-07 → 2002-09-18 |
| 133 | New Cart Design |  |  |  |  |  |  | resources ME TECH → HS Intern; baseline finish 2002-05-24 → 2002-07-05 |
| 134 | New Lifitng Gear |  |  |  |  |  |  | resources ME TECH → HS Intern; baseline finish 2002-05-31 → 2002-07-05 |
| 135 | Sphere Lift Mechanism |  |  |  |  |  |  | baseline start 2002-05-21 → 2002-09-05; baseline finish 2002-06-03 → 2002-09-18 |
| 137 | Lifting I beam in Lab |  | 2002-06-05 → 2002-07-30 (+55d) | 5d → 6d | 50% → 42% | 119d → 80.5d |  |  |
| 138 | Cable trays nad outlets in lab ceiling | 2002-07-15 → 2002-07-29 (+14d) | 2002-07-19 → 2002-08-02 (+14d) |  |  | 87d → 77d |  | constraint start no earlier than 2002-07-14 → start no earlier than 2002-07-27; baseline start 2002-06-03 → 2002-07-15; baseline finish 2002-06-07 → 2002-07-19 |
| 139 | **Sensor & Payload Mounts** |  |  |  |  |  |  | baseline start 2002-05-20 → 2002-06-21; baseline finish 2002-05-28 → 2002-06-27 |
| 140 | Antennaes |  |  |  |  |  |  | baseline start 2002-05-20 → 2002-06-21; baseline finish 2002-05-24 → 2002-06-27 |
| 141 | ORE & various equip |  |  |  |  |  |  | baseline start 2002-05-23 → 2002-06-24; baseline finish 2002-05-28 → 2002-06-27 |
| 142 | **Buoyancy** | 2002-06-13 A | 2002-07-11 → 2002-08-23 (+43d) | 21d → 51.4d | 0% → 9% | 85d → 54.6d |  | baseline start 2002-05-22 → 2002-06-13; baseline finish 2002-06-04 → 2002-07-11 |
| 143 | Tailcone Foam Pack Specification | 2002-06-28 → 2002-07-17 (+19d) | 2002-07-04 → 2002-07-23 (+19d) |  |  | 85d → 72d |  | constraint start no earlier than 2002-06-28 → start no earlier than 2002-07-17; baseline start 2002-05-22 → 2002-06-28; baseline finish 2002-05-28 → 2002-07-04 |
| 144 | Tailcone foam machining | 2002-07-05 → 2002-07-24 (+19d) | 2002-07-11 → 2002-07-30 (+19d) |  |  | 85d → 72d |  | baseline start 2002-05-29 → 2002-07-05; baseline finish 2002-06-04 → 2002-07-11 |
| 145 | Modular trim / ballast systems concept | 2002-06-13 A | 2002-06-24 → 2002-08-23 (+60d) |  | 0% → 20% | 98d → 54.6d |  | baseline start 2002-05-22 → 2002-06-13; baseline finish 2002-05-28 → 2002-06-24 |
| 146 | **Fairing Build** | 2002-07-12 → 2002-08-23 (+42d) | 2002-07-23 → 2002-09-04 (+43d) |  |  | 85d → 54.6d |  | baseline start 2002-06-10 → 2002-07-12; baseline finish 2002-06-26 → 2002-07-23 |
| 147 | Noes section (2 plus 1 spare) | 2002-07-12 → 2002-08-23 (+42d) | 2002-07-23 → 2002-09-04 (+43d) |  |  | 85d → 54.6d |  | baseline start 2002-06-10 → 2002-07-12; baseline finish 2002-06-19 → 2002-07-23 |
| 148 | Midboady (2 plus 1 spare) | 2002-07-12 → 2002-08-23 (+42d) | 2002-07-23 → 2002-09-04 (+43d) |  |  | 85d → 54.6d |  | baseline start 2002-06-13 → 2002-07-12; baseline finish 2002-06-24 → 2002-07-23 |
| 149 | Tail section (2 plus 1 spare) | 2002-07-12 → 2002-08-23 (+42d) | 2002-07-23 → 2002-09-04 (+43d) |  |  | 85d → 54.6d |  | baseline start 2002-06-17 → 2002-07-12; baseline finish 2002-06-26 → 2002-07-23 |
| 151 | **Software** | 2002-06-06 A → 2002-06-29 A (+23d) |  | 119d → 102d |  |  |  | baseline start 2002-06-24 → 2002-06-06 |
| 157 | **GUI** | 2002-06-06 → 2002-09-02 (+88d) | 2002-08-14 → 2002-11-08 (+86d) |  |  | 69d → 7d |  | baseline start 2002-07-02 → 2002-06-06; baseline finish 2002-09-09 → 2002-08-14 |
| 158 | gather requirements | 2002-06-06 → 2002-09-02 (+88d) | 2002-06-12 → 2002-09-06 (+86d) |  |  | 69d → 7d |  | constraint start no earlier than 2002-06-06 → start no earlier than 2002-09-01; baseline start 2002-07-02 → 2002-06-06; baseline finish 2002-07-08 → 2002-06-12 |
| 159 | eval Bluefin GUI | 2002-06-13 → 2002-09-09 (+88d) | 2002-06-26 → 2002-09-20 (+86d) |  |  | 69d → 7d |  | baseline start 2002-07-09 → 2002-06-13; baseline finish 2002-07-22 → 2002-06-26 |
| 160 | develop GUI plan | 2002-06-27 → 2002-09-23 (+88d) | 2002-07-03 → 2002-09-27 (+86d) |  |  | 69d → 7d |  | baseline start 2002-07-23 → 2002-06-27; baseline finish 2002-07-29 → 2002-07-03 |
| 161 | Detail GUI development (TBD) | 2002-07-04 → 2002-09-30 (+88d) | 2002-08-14 → 2002-11-08 (+86d) |  |  | 69d → 7d |  | baseline start 2002-07-30 → 2002-07-04; baseline finish 2002-09-09 → 2002-08-14 |
| 162 | Configuration management on vehicle (config files) |  |  |  |  |  |  | baseline start 2002-08-16 → 2002-07-09; baseline finish 2002-09-05 → 2002-07-29 |
| 163 | **Controls** | 2002-07-19 → 2002-09-02 (+45d) | 2002-09-19 → 2002-11-01 (+43d) |  |  | 43d → 12d |  | baseline start 2002-06-24 → 2002-07-19; baseline finish 2002-08-23 → 2002-09-19 |
| 164 | depth control improvement (long configs) | 2002-07-19 → 2002-09-02 (+45d) | 2002-08-08 → 2002-09-20 (+43d) |  |  | 43d → 12d |  | constraint start no earlier than 2002-07-19 → start no earlier than 2002-08-31; baseline start 2002-06-24 → 2002-07-19; baseline finish 2002-07-12 → 2002-08-08 |
| 165 | sway / yaw control coupling (heave/ pitch too) | 2002-08-09 → 2002-09-23 (+45d) | 2002-08-22 → 2002-10-04 (+43d) |  |  | 43d → 12d |  | baseline start 2002-07-15 → 2002-08-09; baseline finish 2002-07-26 → 2002-08-22 |
| 166 | slow speed dynamics for control | 2002-08-23 → 2002-10-07 (+45d) | 2002-09-19 → 2002-11-01 (+43d) |  |  | 43d → 12d |  | baseline start 2002-07-29 → 2002-08-23; baseline finish 2002-08-23 → 2002-09-19 |
| 167 | **Navigation Software** | 2002-09-23 A → 2002-06-29 A (-86d) |  | 42d → 102d |  |  |  |  |
| 172 | DVL driver enhancements for PD5 | 2002-10-09 A → 2002-06-29 A (-102d) | 2002-10-29 → 2002-07-19 (-102d) |  |  | 15d → 87d | 169 → none |  |
| 177 | **Vehicle Integration and Test** | 2002-07-18 → 2002-09-02 (+46d) | 2002-09-04 → 2002-10-21 (+47d) | 35d → 36d |  | 53d → 20d |  | baseline start 2002-06-10 → 2002-07-18; baseline finish 2002-08-02 → 2002-09-04 |
| 178 | Tailcone Assembly | 2002-07-18 → 2002-09-02 (+46d) | 2002-07-24 → 2002-09-06 (+44d) |  |  | 62d → 30d |  | constraint start no earlier than 2002-07-18 → start no earlier than 2002-09-02; baseline start 2002-06-10 → 2002-07-18; baseline finish 2002-06-14 → 2002-07-24 |
| 179 | Tailcone Test | 2002-07-25 → 2002-09-09 (+46d) | 2002-07-30 → 2002-09-12 (+44d) |  |  | 62d → 30d |  | baseline start 2002-06-17 → 2002-07-25; baseline finish 2002-06-20 → 2002-07-30 |
| 180 | Battery Midbody Integration | 2002-07-31 → 2002-09-11 (+42d) | 2002-08-06 → 2002-09-17 (+42d) |  |  | 53d → 23d |  | constraint start no earlier than 2002-07-31 → start no earlier than 2002-09-11; baseline start 2002-06-17 → 2002-07-31; baseline finish 2002-06-21 → 2002-08-06 |
| 181 | Battery Midbody Test | 2002-08-07 → 2002-09-18 (+42d) | 2002-08-12 → 2002-09-23 (+42d) |  |  | 53d → 23d |  | baseline start 2002-06-24 → 2002-08-07; baseline finish 2002-06-27 → 2002-08-12 |
| 182 | ALTEX Nose Payload Assembly/Upgrade | 2002-07-19 → 2002-09-09 (+52d) | 2002-07-25 → 2002-09-13 (+50d) |  |  | 56d → 20d |  | constraint start no earlier than 2002-07-19 → start no earlier than 2002-09-08; baseline start 2002-06-17 → 2002-07-19; baseline finish 2002-06-21 → 2002-07-25 |
| 183 | Science Payload Assembly | 2002-07-26 → 2002-09-16 (+52d) | 2002-08-02 → 2002-09-23 (+52d) |  |  | 56d → 20d |  | baseline start 2002-06-24 → 2002-07-26; baseline finish 2002-07-01 → 2002-08-02 |
| 184 | Payload Test | 2002-08-05 → 2002-09-24 (+50d) | 2002-08-07 → 2002-09-26 (+50d) |  |  | 56d → 20d |  | baseline start 2002-07-02 → 2002-08-05; baseline finish 2002-07-04 → 2002-08-07 |
| 185 | Integrated Vehcile Deck Assembly | 2002-08-13 → 2002-09-27 (+45d) | 2002-08-14 → 2002-09-30 (+47d) |  |  | 53d → 20d |  | baseline start 2002-07-05 → 2002-08-13; baseline finish 2002-07-08 → 2002-08-14 |
| 186 | Vehicle Ballasting | 2002-08-15 → 2002-10-01 (+47d) | 2002-08-15 → 2002-10-01 (+47d) |  |  | 53d → 20d |  | baseline start 2002-07-09 → 2002-08-15; baseline finish 2002-07-09 → 2002-08-15 |
| 187 | Integrated Vehicle Deck Test | 2002-08-16 → 2002-10-02 (+47d) | 2002-08-20 → 2002-10-04 (+45d) |  |  | 53d → 20d |  | baseline start 2002-07-10 → 2002-08-16; baseline finish 2002-07-12 → 2002-08-20 |
| 188 | Integrated Vehicle Tank Test | 2002-08-21 → 2002-10-07 (+47d) | 2002-08-27 → 2002-10-11 (+45d) |  |  | 53d → 20d |  | baseline start 2002-07-15 → 2002-08-21; baseline finish 2002-07-19 → 2002-08-27 |
| 189 | Integrated Vehicle Sea Trials | 2002-08-28 → 2002-10-14 (+47d) | 2002-09-04 → 2002-10-21 (+47d) |  |  | 53d → 20d |  | baseline start 2002-07-22 → 2002-08-28; baseline finish 2002-08-02 → 2002-09-04 |
| 191 | **CTD Science Payload Core** |  | 2002-09-05 → 2002-10-22 (+47d) | 51d? → 84d? |  | 53d → 20d |  | baseline start 2002-06-20 → 2002-06-27; baseline finish 2002-08-05 → 2002-09-05 |
| 192 | Repair/Replace nose fairing | 2002-07-22 → 2002-07-12 (-10d) | 2002-07-24 → 2002-07-16 (-8d) |  |  | 78d → 84d |  | constraint start no earlier than 2002-07-20 → start no earlier than 2002-07-12; baseline start 2002-06-20 → 2002-07-22; baseline finish 2002-06-24 → 2002-07-24 |
| 193 | recable Dcon to comms and pwr bus | 2002-07-29 → 2002-07-18 (-11d) | 2002-08-07 → 2002-07-29 (-9d) |  |  | 70d → 77d |  | constraint start no earlier than 2002-07-27 → start no earlier than 2002-07-18; baseline start 2002-06-21 → 2002-07-29; baseline finish 2002-07-02 → 2002-08-07 |
| 194 | Design HS2 Mount | 2002-07-25 → 2002-07-17 (-8d) | 2002-07-26 → 2002-07-18 (-8d) |  |  | 78d → 84d |  | baseline start 2002-06-25 → 2002-07-25; baseline finish 2002-06-26 → 2002-07-26 |
| 195 | Build HS2 Mount | 2002-07-29 → 2002-07-19 (-10d) | 2002-07-30 → 2002-07-22 (-8d) |  |  | 78d → 84d |  | baseline start 2002-06-27 → 2002-07-29; baseline finish 2002-06-28 → 2002-07-30 |
| 196 | Assembly HS2 Mount | 2002-07-31 → 2002-07-23 (-8d) | 2002-08-01 → 2002-07-24 (-8d) |  |  | 78d → 84d |  | baseline start 2002-07-01 → 2002-07-31; baseline finish 2002-07-02 → 2002-08-01 |
| 199 | repair flow sensor #2 | 2002-08-08 → 2002-07-30 (-9d) | 2002-08-12 → 2002-08-01 (-11d) |  |  | 70d → 77d |  | baseline start 2002-07-03 → 2002-08-08; baseline finish 2002-07-05 → 2002-08-12 |
| 200 | test integrated CTD Payload | 2002-09-05 → 2002-10-22 (+47d) | 2002-09-05 → 2002-10-22 (+47d) |  |  | 53d → 20d |  | baseline start 2002-08-05 → 2002-09-05; baseline finish 2002-08-05 → 2002-09-05 |

| ID | Task | Start | Finish | Duration | Total float | Other |
| --- | --- | --- | --- | --- | --- | --- |
| 202 | **CTD Extension for Ryan/Haddock** |  |  |  |  | baseline start 2002-06-03 → 2002-06-27; baseline finish 2002-07-01 → 2002-07-25 |
| 203 | Design LISST pump assy |  |  |  |  | baseline start 2002-06-03 → 2002-06-27; baseline finish 2002-06-06 → 2002-07-02 |
| 204 | Fab LISST pump assy |  |  |  |  | baseline start 2002-06-07 → 2002-07-03; baseline finish 2002-06-13 → 2002-07-09 |
| 205 | Assy LISST pump into vehicle |  |  |  |  | baseline start 2002-06-14 → 2002-07-10; baseline finish 2002-06-17 → 2002-07-11 |
| 206 | Design LISST mount |  |  |  |  | baseline start 2002-06-07 → 2002-07-03; baseline finish 2002-06-13 → 2002-07-09 |
| 207 | Fab LISST Mount |  |  |  |  | baseline start 2002-06-14 → 2002-07-10; baseline finish 2002-06-20 → 2002-07-16 |
| 208 | Assy LISST mount |  |  |  |  | baseline start 2002-06-21 → 2002-07-17; baseline finish 2002-06-24 → 2002-07-18 |
| 209 | Cable LISST to Dcon |  |  |  |  | baseline start 2002-06-25 → 2002-07-19; baseline finish 2002-06-25 → 2002-07-19 |
| 210 | Write Test Driver for LISST |  |  |  |  | baseline start 2002-06-25 → 2002-07-19; baseline finish 2002-07-01 → 2002-07-25 |
| 211 | Design Bathypho mount |  |  |  |  | baseline start 2002-06-05 → 2002-07-03; baseline finish 2002-06-10 → 2002-07-08 |
| 212 | Fab Bathypho mount |  |  |  |  | baseline start 2002-06-11 → 2002-07-09; baseline finish 2002-06-17 → 2002-07-15 |
| 213 | Assy Bathypho mount |  |  |  |  | baseline start 2002-06-18 → 2002-07-16; baseline finish 2002-06-19 → 2002-07-17 |
| 214 | Cable Bathypho to Dcon |  |  |  |  | baseline start 2002-06-20 → 2002-07-18; baseline finish 2002-06-20 → 2002-07-18 |
| 215 | Retest driver for Bathypho (already written) |  |  |  |  | baseline start 2002-06-21 → 2002-07-19; baseline finish 2002-06-25 → 2002-07-23 |
| 217 | **Ryan / Haddock Cruise Prep** | 2002-08-05 → 2002-06-26 (-40d) | 2002-08-22 → 2002-08-29 (+7d) | 14d → 47d? | 63d → 58d | constraint start no earlier than 2002-08-05 → none; baseline start 2002-07-29 → 2002-08-05; baseline finish 2002-08-15 → 2002-08-22 |
